# Design-Build CSTv1.3

Schedule from Primavera P6, 2023-01-01 to 2025-07-08, data date 2023-01-01, costs in USD.

## Calendars

- Cal01-5d/8hr/12hol: Mon-Fri 08:00-16:00; Sat-Sun off. Exceptions (off unless hours are given): 2023-01-02, 2023-01-16, 2023-02-20, 2023-04-17, 2023-05-29, 2023-06-19, 2023-07-04, 2023-09-04, 2023-10-09, 2023-11-23, 2023-12-25, 2024-01-01, 2024-01-15, 2024-02-19, 2024-04-15, 2024-05-27, 2024-06-19, 2024-07-04, 2024-09-02, 2024-10-14, 2024-11-11, 2024-11-28, 2024-12-25, 2025-01-01, 2025-01-20, 2025-02-17, 2025-04-21, 2025-05-26, 2025-06-19, 2025-07-04.
- Cal03A - 7d/8hr/No Holidays: Mon-Sun 08:00-16:00.
- Cal04-7d/24Hr/No Hol (Milestones): Mon-Sun 00:00-00:00.
- Cal12-Paving 5d/12hol: Mon-Fri 08:00-16:00; Sat-Sun off. Exceptions (off unless hours are given): 2023-01-02 to 2023-01-06, 2023-01-09 to 2023-01-13, 2023-01-16 to 2023-01-20, 2023-01-23 to 2023-01-27, 2023-01-30 to 2023-02-03, 2023-02-06 to 2023-02-10, 2023-02-13 to 2023-02-17, 2023-02-20 to 2023-02-24, 2023-02-27 to 2023-03-03, 2023-03-06 to 2023-03-10, 2023-03-13 to 2023-03-17, 2023-03-20 to 2023-03-24, 2023-03-27 to 2023-03-31, 2023-04-17, 2023-05-29, 2023-06-19, 2023-07-04, 2023-09-04, 2023-10-09, 2023-11-15 to 2023-11-17, 2023-11-20 to 2023-11-24, 2023-11-27 to 2023-12-01, 2023-12-04 to 2023-12-08, 2023-12-11 to 2023-12-15, 2023-12-18 to 2023-12-22, 2023-12-25 to 2023-12-29, 2024-01-01 to 2024-01-05, 2024-01-08 to 2024-01-12, 2024-01-15 to 2024-01-19, 2024-01-22 to 2024-01-26, 2024-01-29 to 2024-02-02, 2024-02-05 to 2024-02-09, 2024-02-12 to 2024-02-16, 2024-02-19 to 2024-02-23, 2024-02-26 to 2024-03-01, 2024-03-04 to 2024-03-08, 2024-03-11 to 2024-03-15, 2024-03-18 to 2024-03-22, 2024-03-25 to 2024-03-29, 2024-04-15, 2024-05-27, 2024-06-19, 2024-07-04, 2024-09-02, 2024-10-14, 2024-11-11, 2024-11-15, 2024-11-18 to 2024-11-22, 2024-11-25 to 2024-11-29, 2024-12-02 to 2024-12-06, 2024-12-09 to 2024-12-13, 2024-12-16 to 2024-12-20, 2024-12-23 to 2024-12-27, 2024-12-30 to 2025-01-03, 2025-01-06 to 2025-01-10, 2025-01-13 to 2025-01-17, 2025-01-20 to 2025-01-24, 2025-01-27 to 2025-01-31, 2025-02-03 to 2025-02-07, 2025-02-10 to 2025-02-14, 2025-02-17 to 2025-02-21, 2025-02-24 to 2025-02-28, 2025-03-03 to 2025-03-07, 2025-03-10 to 2025-03-14, 2025-03-17 to 2025-03-21, 2025-03-24 to 2025-03-28, 2025-03-31, 2025-04-21, 2025-05-26, 2025-06-19, 2025-07-04.
- Cal15-Wtr Acc 1-5d/12hol: Mon-Fri 08:00-16:00; Sat-Sun off. Exceptions (off unless hours are given): 2023-01-02 to 2023-01-06, 2023-01-09 to 2023-01-13, 2023-01-16 to 2023-01-20, 2023-01-23 to 2023-01-27, 2023-01-30 to 2023-02-03, 2023-02-06 to 2023-02-10, 2023-02-13 to 2023-02-17, 2023-02-20 to 2023-02-24, 2023-02-27 to 2023-03-03, 2023-03-06 to 2023-03-10, 2023-03-13 to 2023-03-17, 2023-03-20 to 2023-03-24, 2023-03-27 to 2023-03-31, 2023-04-03 to 2023-04-07, 2023-04-10 to 2023-04-14, 2023-04-17 to 2023-04-21, 2023-04-24 to 2023-04-28, 2023-05-01 to 2023-05-05, 2023-05-08 to 2023-05-12, 2023-05-15 to 2023-05-19, 2023-05-22 to 2023-05-26, 2023-05-29 to 2023-05-31, 2023-06-19, 2023-07-04, 2023-09-04, 2023-10-02 to 2023-10-06, 2023-10-09 to 2023-10-13, 2023-10-16 to 2023-10-20, 2023-10-23 to 2023-10-27, 2023-10-30 to 2023-11-03, 2023-11-06 to 2023-11-10, 2023-11-13 to 2023-11-17, 2023-11-20 to 2023-11-24, 2023-11-27 to 2023-12-01, 2023-12-04 to 2023-12-08, 2023-12-11 to 2023-12-15, 2023-12-18 to 2023-12-22, 2023-12-25 to 2023-12-29, 2024-01-01 to 2024-01-05, 2024-01-08 to 2024-01-12, 2024-01-15 to 2024-01-19, 2024-01-22 to 2024-01-26, 2024-01-29 to 2024-02-02, 2024-02-05 to 2024-02-09, 2024-02-12 to 2024-02-16, 2024-02-19 to 2024-02-23, 2024-02-26 to 2024-03-01, 2024-03-04 to 2024-03-08, 2024-03-11 to 2024-03-15, 2024-03-18 to 2024-03-22, 2024-03-25 to 2024-03-29, 2024-04-01 to 2024-04-05, 2024-04-08 to 2024-04-12, 2024-04-15 to 2024-04-19, 2024-04-22 to 2024-04-26, 2024-04-29 to 2024-05-03, 2024-05-06 to 2024-05-10, 2024-05-13 to 2024-05-17, 2024-05-20 to 2024-05-24, 2024-05-27 to 2024-05-31, 2024-06-19, 2024-07-04, 2024-09-02, 2024-10-01 to 2024-10-04, 2024-10-07 to 2024-10-11, 2024-10-14 to 2024-10-18, 2024-10-21 to 2024-10-25, 2024-10-28 to 2024-11-01, 2024-11-04 to 2024-11-08, 2024-11-11 to 2024-11-15, 2024-11-18 to 2024-11-22, 2024-11-25 to 2024-11-29, 2024-12-02 to 2024-12-06, 2024-12-09 to 2024-12-13, 2024-12-16 to 2024-12-20, 2024-12-23 to 2024-12-27, 2024-12-30 to 2025-01-03, 2025-01-06 to 2025-01-10, 2025-01-13 to 2025-01-17, 2025-01-20 to 2025-01-24, 2025-01-27 to 2025-01-31, 2025-02-03 to 2025-02-07, 2025-02-10 to 2025-02-14, 2025-02-17 to 2025-02-21, 2025-02-24 to 2025-02-28, 2025-03-03 to 2025-03-07, 2025-03-10 to 2025-03-14, 2025-03-17 to 2025-03-21, 2025-03-24 to 2025-03-28, 2025-03-31 to 2025-04-04, 2025-04-07 to 2025-04-11, 2025-04-14 to 2025-04-18, 2025-04-21 to 2025-04-25, 2025-04-28 to 2025-05-02, 2025-05-05 to 2025-05-09, 2025-05-12 to 2025-05-16, 2025-05-19 to 2025-05-23, 2025-05-26 to 2025-05-30, 2025-06-19, 2025-07-04.
- Cal19 - Saturday Only (Advert): Mon-Fri off; Sat 08:00-16:00; Sun off.
- Cal13-Planting 5d/12hol - Evergreen: Mon-Fri 08:00-16:00; Sat-Sun off. Exceptions (off unless hours are given): 2023-01-02 to 2023-01-06, 2023-01-09 to 2023-01-13, 2023-01-16 to 2023-01-20, 2023-01-23 to 2023-01-27, 2023-01-30 to 2023-02-03, 2023-02-06 to 2023-02-10, 2023-02-13 to 2023-02-17, 2023-02-20 to 2023-02-24, 2023-02-27 to 2023-03-03, 2023-03-06 to 2023-03-10, 2023-03-13 to 2023-03-17, 2023-03-20 to 2023-03-24, 2023-03-27 to 2023-03-31, 2023-04-03 to 2023-04-07, 2023-04-10 to 2023-04-14, 2023-04-17, 2023-05-29, 2023-06-01 to 2023-06-02, 2023-06-05 to 2023-06-09, 2023-06-12 to 2023-06-16, 2023-06-19 to 2023-06-23, 2023-06-26 to 2023-06-30, 2023-07-03 to 2023-07-07, 2023-07-10 to 2023-07-14, 2023-07-17 to 2023-07-21, 2023-07-24 to 2023-07-28, 2023-07-31 to 2023-08-04, 2023-08-07 to 2023-08-11, 2023-08-14 to 2023-08-15, 2023-09-04, 2023-10-09, 2023-10-16 to 2023-10-20, 2023-10-23 to 2023-10-27, 2023-10-30 to 2023-11-03, 2023-11-06 to 2023-11-10, 2023-11-13 to 2023-11-17, 2023-11-20 to 2023-11-24, 2023-11-27 to 2023-12-01, 2023-12-04 to 2023-12-08, 2023-12-11 to 2023-12-15, 2023-12-18 to 2023-12-22, 2023-12-25 to 2023-12-29, 2024-01-01 to 2024-01-05, 2024-01-08 to 2024-01-12, 2024-01-15 to 2024-01-19, 2024-01-22 to 2024-01-26, 2024-01-29 to 2024-02-02, 2024-02-05 to 2024-02-09, 2024-02-12 to 2024-02-16, 2024-02-19 to 2024-02-23, 2024-02-26 to 2024-03-01, 2024-03-04 to 2024-03-08, 2024-03-11 to 2024-03-15, 2024-03-18 to 2024-03-22, 2024-03-25 to 2024-03-29, 2024-04-01 to 2024-04-05, 2024-04-08 to 2024-04-12, 2024-04-15, 2024-05-27, 2024-06-03 to 2024-06-07, 2024-06-10 to 2024-06-14, 2024-06-17 to 2024-06-21, 2024-06-24 to 2024-06-28, 2024-07-01 to 2024-07-05, 2024-07-08 to 2024-07-12, 2024-07-15 to 2024-07-19, 2024-07-22 to 2024-07-26, 2024-07-29 to 2024-08-02, 2024-08-05 to 2024-08-09, 2024-08-12 to 2024-08-15, 2024-09-02, 2024-10-14, 2024-10-16 to 2024-10-18, 2024-10-21 to 2024-10-25, 2024-10-28 to 2024-11-01, 2024-11-04 to 2024-11-08, 2024-11-11 to 2024-11-15, 2024-11-18 to 2024-11-22, 2024-11-25 to 2024-11-29, 2024-12-02 to 2024-12-06, 2024-12-09 to 2024-12-13, 2024-12-16 to 2024-12-20, 2024-12-23 to 2024-12-27, 2024-12-30 to 2025-01-03, 2025-01-06 to 2025-01-10, 2025-01-13 to 2025-01-17, 2025-01-20 to 2025-01-24, 2025-01-27 to 2025-01-31, 2025-02-03 to 2025-02-07, 2025-02-10 to 2025-02-14, 2025-02-17 to 2025-02-21, 2025-02-24 to 2025-02-28, 2025-03-03 to 2025-03-07, 2025-03-10 to 2025-03-14, 2025-03-17 to 2025-03-21, 2025-03-24 to 2025-03-28, 2025-03-31 to 2025-04-04, 2025-04-07 to 2025-04-11, 2025-04-14 to 2025-04-15, 2025-04-21, 2025-05-26, 2025-06-02 to 2025-06-06, 2025-06-09 to 2025-06-13, 2025-06-16 to 2025-06-20, 2025-06-23 to 2025-06-27, 2025-06-30 to 2025-07-04, 2025-07-07 to 2025-07-08.
- Cal03-7d/8hr/12hol: Mon-Sun 08:00-16:00. Exceptions (off unless hours are given): 2023-01-01, 2023-01-16, 2023-02-20, 2023-04-17, 2023-05-29, 2023-06-19, 2023-07-04, 2023-09-04, 2023-10-09, 2023-11-11, 2023-11-23, 2023-12-25, 2024-01-01, 2024-01-15, 2024-02-19, 2024-04-15, 2024-05-27, 2024-06-19, 2024-07-04, 2024-09-02, 2024-10-14, 2024-11-11, 2024-11-28, 2024-12-25, 2025-01-01, 2025-01-20, 2025-02-17, 2025-04-21, 2025-05-26, 2025-06-19, 2025-07-04.
- Cal10-Wntr Ineff 5d/12hol: Mon-Fri 08:00-16:00; Sat-Sun off. Exceptions (off unless hours are given): 2023-01-02, 2023-01-04, 2023-01-11 to 2023-01-12, 2023-01-16, 2023-01-19, 2023-01-25 to 2023-01-26, 2023-02-01 to 2023-02-02, 2023-02-08 to 2023-02-09, 2023-02-15 to 2023-02-16, 2023-02-20, 2023-02-23, 2023-03-01, 2023-03-08, 2023-04-17, 2023-05-29, 2023-06-19, 2023-07-04, 2023-09-04, 2023-10-09, 2023-11-23, 2023-12-20 to 2023-12-21, 2023-12-25, 2023-12-28, 2024-01-01, 2024-01-04, 2024-01-10 to 2024-01-11, 2024-01-15, 2024-01-18, 2024-01-24 to 2024-01-25, 2024-01-31 to 2024-02-01, 2024-02-07 to 2024-02-08, 2024-02-14 to 2024-02-15, 2024-02-19, 2024-02-22, 2024-02-28 to 2024-02-29, 2024-03-06, 2024-03-13, 2024-04-15, 2024-05-27, 2024-06-19, 2024-07-04, 2024-09-02, 2024-10-14, 2024-11-11, 2024-11-28, 2024-12-18 to 2024-12-19, 2024-12-25 to 2024-12-26, 2025-01-01 to 2025-01-02, 2025-01-08 to 2025-01-09, 2025-01-15 to 2025-01-16, 2025-01-20, 2025-01-23, 2025-01-29 to 2025-01-30, 2025-02-05 to 2025-02-06, 2025-02-12 to 2025-02-13, 2025-02-17, 2025-02-20, 2025-02-26 to 2025-02-27, 2025-03-05, 2025-03-12, 2025-04-21, 2025-05-26, 2025-06-19, 2025-07-04.
- Cal11-Wntr Shut 5d/12hol: Mon-Fri 08:00-16:00; Sat-Sun off. Exceptions (off unless hours are given): 2023-01-02 to 2023-01-06, 2023-01-09 to 2023-01-13, 2023-01-16 to 2023-01-20, 2023-01-23 to 2023-01-27, 2023-01-30 to 2023-02-03, 2023-02-06 to 2023-02-10, 2023-02-13 to 2023-02-17, 2023-02-20 to 2023-02-24, 2023-02-27 to 2023-03-03, 2023-03-06 to 2023-03-10, 2023-03-13 to 2023-03-15, 2023-04-17, 2023-05-29, 2023-06-19, 2023-07-04, 2023-09-04, 2023-10-09, 2023-11-23, 2023-12-01, 2023-12-04 to 2023-12-08, 2023-12-11 to 2023-12-15, 2023-12-18 to 2023-12-22, 2023-12-25 to 2023-12-29, 2024-01-01 to 2024-01-05, 2024-01-08 to 2024-01-12, 2024-01-15 to 2024-01-19, 2024-01-22 to 2024-01-26, 2024-01-29 to 2024-02-02, 2024-02-05 to 2024-02-09, 2024-02-12 to 2024-02-16, 2024-02-19 to 2024-02-23, 2024-02-26 to 2024-03-01, 2024-03-04 to 2024-03-08, 2024-03-11 to 2024-03-15, 2024-04-15, 2024-05-27, 2024-06-19, 2024-07-04, 2024-09-02, 2024-10-14, 2024-11-11, 2024-11-28, 2024-12-02 to 2024-12-06, 2024-12-09 to 2024-12-13, 2024-12-16 to 2024-12-20, 2024-12-23 to 2024-12-27, 2024-12-30 to 2025-01-03, 2025-01-06 to 2025-01-10, 2025-01-13 to 2025-01-17, 2025-01-20 to 2025-01-24, 2025-01-27 to 2025-01-31, 2025-02-03 to 2025-02-07, 2025-02-10 to 2025-02-14, 2025-02-17 to 2025-02-21, 2025-02-24 to 2025-02-28, 2025-03-03 to 2025-03-07, 2025-03-10 to 2025-03-14, 2025-04-21, 2025-05-26, 2025-06-19, 2025-07-04.
- Cal16- Wtr Acc 2-5d/12hol: Mon-Fri 08:00-16:00; Sat-Sun off. Exceptions (off unless hours are given): 2023-01-02, 2023-01-16, 2023-02-20, 2023-04-03 to 2023-04-07, 2023-04-10 to 2023-04-14, 2023-04-17 to 2023-04-21, 2023-04-24 to 2023-04-28, 2023-05-01 to 2023-05-05, 2023-05-08 to 2023-05-12, 2023-05-15 to 2023-05-19, 2023-05-22 to 2023-05-26, 2023-05-29 to 2023-06-02, 2023-06-05 to 2023-06-09, 2023-06-12 to 2023-06-16, 2023-06-19 to 2023-06-23, 2023-06-26 to 2023-06-30, 2023-07-03 to 2023-07-07, 2023-07-10 to 2023-07-14, 2023-09-04, 2023-09-15, 2023-09-18 to 2023-09-22, 2023-09-25 to 2023-09-29, 2023-10-02 to 2023-10-06, 2023-10-09 to 2023-10-13, 2023-10-16 to 2023-10-20, 2023-10-23 to 2023-10-27, 2023-10-30 to 2023-10-31, 2023-11-10, 2023-11-23, 2023-12-25, 2024-01-01, 2024-01-15, 2024-02-19, 2024-04-01 to 2024-04-05, 2024-04-08 to 2024-04-12, 2024-04-15 to 2024-04-19, 2024-04-22 to 2024-04-26, 2024-04-29 to 2024-05-03, 2024-05-06 to 2024-05-10, 2024-05-13 to 2024-05-17, 2024-05-20 to 2024-05-24, 2024-05-27 to 2024-05-31, 2024-06-03 to 2024-06-07, 2024-06-10 to 2024-06-14, 2024-06-17 to 2024-06-21, 2024-06-24 to 2024-06-28, 2024-07-01 to 2024-07-05, 2024-07-08 to 2024-07-12, 2024-07-15, 2024-09-02, 2024-09-16 to 2024-09-20, 2024-09-23 to 2024-09-27, 2024-09-30 to 2024-10-04, 2024-10-07 to 2024-10-11, 2024-10-14 to 2024-10-18, 2024-10-21 to 2024-10-25, 2024-10-28 to 2024-10-31, 2024-11-11, 2024-11-28, 2024-12-25, 2025-01-01, 2025-01-20, 2025-02-17, 2025-04-01 to 2025-04-04, 2025-04-07 to 2025-04-11, 2025-04-14 to 2025-04-18, 2025-04-21 to 2025-04-25, 2025-04-28 to 2025-05-02, 2025-05-05 to 2025-05-09, 2025-05-12 to 2025-05-16, 2025-05-19 to 2025-05-23, 2025-05-26 to 2025-05-30, 2025-06-02 to 2025-06-06, 2025-06-09 to 2025-06-13, 2025-06-16 to 2025-06-20, 2025-06-23 to 2025-06-27, 2025-06-30 to 2025-07-04, 2025-07-07 to 2025-07-08.
- Cal02-6d/8hr/12hol: Mon-Sat 08:00-16:00; Sun off. Exceptions (off unless hours are given): 2023-01-02, 2023-01-16, 2023-02-20, 2023-04-17, 2023-05-29, 2023-06-19, 2023-07-04, 2023-09-04, 2023-10-09, 2023-11-11, 2023-11-23, 2023-12-25, 2024-01-01, 2024-01-15, 2024-02-19, 2024-04-15, 2024-05-27, 2024-06-19, 2024-07-04, 2024-09-02, 2024-10-14, 2024-11-11, 2024-11-28, 2024-12-25, 2025-01-01, 2025-01-20, 2025-02-17, 2025-04-21, 2025-05-26, 2025-06-19, 2025-07-04.
- Cal05-MBTA Night/12hol: Mon-Fri 10:00-14:00; Sat-Sun off. Exceptions (off unless hours are given): 2023-01-02, 2023-01-16, 2023-02-20, 2023-04-17, 2023-05-29, 2023-06-19, 2023-07-04, 2023-09-04, 2023-10-09, 2023-11-23, 2023-12-25, 2024-01-01, 2024-01-15, 2024-02-19, 2024-04-15, 2024-05-27, 2024-06-19, 2024-07-04, 2024-09-02, 2024-10-14, 2024-11-11, 2024-11-28, 2024-12-25, 2025-01-01, 2025-01-20, 2025-02-17, 2025-04-21, 2025-05-26, 2025-06-19, 2025-07-04.
- Cal14-Planting 5d/12hol - Deciduous: Mon-Fri 08:00-16:00; Sat-Sun off. Exceptions (off unless hours are given): 2023-01-02 to 2023-01-06, 2023-01-09 to 2023-01-13, 2023-01-16 to 2023-01-20, 2023-01-23 to 2023-01-27, 2023-01-30 to 2023-02-03, 2023-02-06 to 2023-02-10, 2023-02-13 to 2023-02-17, 2023-02-20 to 2023-02-24, 2023-02-27 to 2023-03-03, 2023-03-06 to 2023-03-10, 2023-03-13 to 2023-03-17, 2023-03-20, 2023-04-17, 2023-05-29, 2023-06-16, 2023-06-19 to 2023-06-23, 2023-06-26 to 2023-06-30, 2023-07-03 to 2023-07-07, 2023-07-10 to 2023-07-14, 2023-07-17 to 2023-07-21, 2023-07-24 to 2023-07-28, 2023-07-31 to 2023-08-04, 2023-08-07 to 2023-08-11, 2023-08-14 to 2023-08-18, 2023-08-21 to 2023-08-25, 2023-08-28 to 2023-09-01, 2023-09-04 to 2023-09-08, 2023-09-11 to 2023-09-15, 2023-09-18 to 2023-09-22, 2023-09-25 to 2023-09-29, 2023-10-09, 2023-11-10, 2023-11-23, 2023-12-04 to 2023-12-08, 2023-12-11 to 2023-12-15, 2023-12-18 to 2023-12-22, 2023-12-25 to 2023-12-29, 2024-01-01 to 2024-01-05, 2024-01-08 to 2024-01-12, 2024-01-15 to 2024-01-19, 2024-01-22 to 2024-01-26, 2024-01-29 to 2024-02-02, 2024-02-05 to 2024-02-09, 2024-02-12 to 2024-02-16, 2024-02-19 to 2024-02-23, 2024-02-26 to 2024-03-01, 2024-03-04 to 2024-03-08, 2024-03-11 to 2024-03-15, 2024-03-18 to 2024-03-20, 2024-04-15, 2024-05-27, 2024-06-17 to 2024-06-21, 2024-06-24 to 2024-06-28, 2024-07-01 to 2024-07-05, 2024-07-08 to 2024-07-12, 2024-07-15 to 2024-07-19, 2024-07-22 to 2024-07-26, 2024-07-29 to 2024-08-02, 2024-08-05 to 2024-08-09, 2024-08-12 to 2024-08-16, 2024-08-19 to 2024-08-23, 2024-08-26 to 2024-08-30, 2024-09-02 to 2024-09-06, 2024-09-09 to 2024-09-13, 2024-09-16 to 2024-09-20, 2024-09-23 to 2024-09-27, 2024-09-30, 2024-10-14, 2024-11-11, 2024-11-28, 2024-12-02 to 2024-12-06, 2024-12-09 to 2024-12-13, 2024-12-16 to 2024-12-20, 2024-12-23 to 2024-12-27, 2024-12-30 to 2025-01-03, 2025-01-06 to 2025-01-10, 2025-01-13 to 2025-01-17, 2025-01-20 to 2025-01-24, 2025-01-27 to 2025-01-31, 2025-02-03 to 2025-02-07, 2025-02-10 to 2025-02-14, 2025-02-17 to 2025-02-21, 2025-02-24 to 2025-02-28, 2025-03-03 to 2025-03-07, 2025-03-10 to 2025-03-14, 2025-03-17 to 2025-03-20, 2025-04-14, 2025-04-21 08:00-16:00, 2025-05-26, 2025-06-02 to 2025-06-06, 2025-06-09 to 2025-06-13, 2025-06-16 to 2025-06-20, 2025-06-23 to 2025-06-27, 2025-06-30 to 2025-07-04, 2025-07-07 to 2025-07-08.
- Cal06-5d/8hr/12hol-Mjr Rdwy: Mon-Fri 08:00-16:00; Sat-Sun off. Exceptions (off unless hours are given): 2023-01-02, 2023-01-16, 2023-02-20, 2023-04-17, 2023-05-12, 2023-05-26, 2023-05-29, 2023-06-19, 2023-07-03 to 2023-07-04, 2023-09-01, 2023-09-04, 2023-10-06, 2023-10-09, 2023-11-21 to 2023-11-24, 2023-12-25, 2024-01-01, 2024-01-15, 2024-02-19, 2024-04-15, 2024-05-10, 2024-05-24, 2024-05-27, 2024-06-19, 2024-07-03 to 2024-07-04, 2024-08-30, 2024-09-02, 2024-10-11, 2024-10-14, 2024-11-11, 2024-11-26 to 2024-11-29, 2024-12-24 to 2024-12-25, 2024-12-31 to 2025-01-01, 2025-01-20, 2025-02-17, 2025-04-21, 2025-05-09, 2025-05-23, 2025-05-26, 2025-06-19, 2025-07-03 to 2025-07-04.
- Cal07-6d/8hr/12hol-MjrRdwy: Mon-Sat 08:00-16:00; Sun off. Exceptions (off unless hours are given): 2023-01-02, 2023-01-14, 2023-01-16, 2023-02-18, 2023-02-20, 2023-04-15, 2023-04-17, 2023-05-12 to 2023-05-13, 2023-05-26 to 2023-05-27, 2023-05-29, 2023-06-19, 2023-07-03 to 2023-07-04, 2023-09-01 to 2023-09-02, 2023-09-04, 2023-10-06 to 2023-10-07, 2023-10-09, 2023-11-11, 2023-11-21 to 2023-11-25, 2023-12-23, 2023-12-25, 2023-12-30, 2024-01-01, 2024-01-13, 2024-01-15, 2024-02-17, 2024-02-19, 2024-04-13, 2024-04-15, 2024-05-10 to 2024-05-11, 2024-05-24 to 2024-05-25, 2024-05-27, 2024-06-19, 2024-07-03 to 2024-07-04, 2024-08-03, 2024-08-30 to 2024-08-31, 2024-09-02, 2024-10-11 to 2024-10-12, 2024-10-14, 2024-11-11, 2024-11-26 to 2024-11-30, 2024-12-24 to 2024-12-25, 2024-12-31 to 2025-01-01, 2025-01-18, 2025-01-20, 2025-02-15, 2025-02-17, 2025-04-19, 2025-04-21, 2025-05-09 to 2025-05-10, 2025-05-23 to 2025-05-24, 2025-05-26, 2025-06-19, 2025-07-03 to 2025-07-04.
- Cal08-7d/8hr/12hol-Mjr Rdwy: Mon-Sun 08:00-16:00. Exceptions (off unless hours are given): 2023-01-01, 2023-01-14 to 2023-01-16, 2023-02-18 to 2023-02-20, 2023-04-15 to 2023-04-17, 2023-05-12 to 2023-05-14, 2023-05-26 to 2023-05-29, 2023-06-19, 2023-07-03 to 2023-07-04, 2023-09-01 to 2023-09-04, 2023-10-06 to 2023-10-09, 2023-11-11, 2023-11-21 to 2023-11-26, 2023-12-23 to 2023-12-25, 2023-12-30 to 2024-01-01, 2024-01-13 to 2024-01-15, 2024-02-17 to 2024-02-19, 2024-04-13 to 2024-04-15, 2024-05-10 to 2024-05-12, 2024-05-24 to 2024-05-27, 2024-06-19, 2024-07-03 to 2024-07-04, 2024-08-30 to 2024-09-02, 2024-10-11 to 2024-10-14, 2024-11-11, 2024-11-26 to 2024-12-01, 2024-12-24 to 2024-12-25, 2024-12-31 to 2025-01-01, 2025-01-18 to 2025-01-20, 2025-02-15 to 2025-02-17, 2025-04-19 to 2025-04-21, 2025-05-09 to 2025-05-11, 2025-05-23 to 2025-05-26, 2025-06-19, 2025-07-03 to 2025-07-04.
- Cal18 - Weekend Shutdown: Mon 09:30-14:30; Tue-Thu off; Fri 10:00-14:00; Sat-Sun 00:00-00:00. Exceptions (off unless hours are given): 2023-01-01 to 2023-01-02, 2023-01-13 to 2023-01-16, 2023-02-17 to 2023-02-20, 2023-04-14 to 2023-04-17, 2023-05-26 to 2023-05-29, 2023-06-16 to 2023-06-19, 2023-06-30 to 2023-07-04, 2023-09-01 to 2023-09-04, 2023-10-06 to 2023-10-09, 2023-11-10 to 2023-11-13, 2023-11-23 to 2023-11-27, 2023-12-22 to 2023-12-25, 2023-12-29 to 2024-01-01, 2024-01-12 to 2024-01-15, 2024-02-16 to 2024-02-19, 2024-04-12 to 2024-04-15, 2024-05-24 to 2024-05-27, 2024-06-19, 2024-06-28 to 2024-07-01, 2024-07-04 to 2024-07-08, 2024-08-30 to 2024-09-02, 2024-10-11 to 2024-10-14, 2024-11-08 to 2024-11-11, 2024-11-28, 2024-12-22 to 2024-12-23, 2024-12-27 to 2024-12-30, 2025-01-01, 2025-01-03 to 2025-01-06 08:00-16:00, 2025-01-17 to 2025-01-20, 2025-02-14 to 2025-02-17, 2025-04-18 to 2025-04-21, 2025-05-23 to 2025-05-26, 2025-06-19, 2025-07-04 to 2025-07-07.
- Cal17 - Reclaimation - 5d/12hol: Mon-Fri 08:00-16:00; Sat-Sun off. Exceptions (off unless hours are given): 2023-01-02 to 2023-01-06, 2023-01-09 to 2023-01-13, 2023-01-16 to 2023-01-20, 2023-01-23 to 2023-01-27, 2023-01-30 to 2023-02-03, 2023-02-06 to 2023-02-10, 2023-02-13 to 2023-02-17, 2023-02-20 to 2023-02-24, 2023-02-27 to 2023-03-03, 2023-03-06 to 2023-03-10, 2023-03-13 to 2023-03-17, 2023-03-20 to 2023-03-24, 2023-03-27 to 2023-03-31, 2023-04-03 to 2023-04-07, 2023-04-10 to 2023-04-14, 2023-04-17, 2023-05-29, 2023-06-19, 2023-07-04, 2023-09-04, 2023-10-09, 2023-10-16 to 2023-10-20, 2023-10-23 to 2023-10-27, 2023-10-30 to 2023-11-03, 2023-11-06 to 2023-11-10, 2023-11-13 to 2023-11-17, 2023-11-20 to 2023-11-24, 2023-11-27 to 2023-12-01, 2023-12-04 to 2023-12-08, 2023-12-11 to 2023-12-15, 2023-12-18 to 2023-12-22, 2023-12-25 to 2023-12-29, 2024-01-01 to 2024-01-05, 2024-01-08 to 2024-01-12, 2024-01-15 to 2024-01-19, 2024-01-22 to 2024-01-26, 2024-01-29 to 2024-02-02, 2024-02-05 to 2024-02-09, 2024-02-12 to 2024-02-16, 2024-02-19 to 2024-02-23, 2024-02-26 to 2024-03-01, 2024-03-04 to 2024-03-08, 2024-03-11 to 2024-03-15, 2024-03-18 to 2024-03-22, 2024-03-25 to 2024-03-29, 2024-04-01 to 2024-04-05, 2024-04-08 to 2024-04-12, 2024-04-15, 2024-05-27, 2024-06-19, 2024-07-04, 2024-09-02, 2024-10-14 to 2024-10-18, 2024-10-21 to 2024-10-25, 2024-10-28 to 2024-11-01, 2024-11-04 to 2024-11-08, 2024-11-11 to 2024-11-15, 2024-11-18 to 2024-11-22, 2024-11-25 to 2024-11-29, 2024-12-02 to 2024-12-06, 2024-12-09 to 2024-12-13, 2024-12-16 to 2024-12-20, 2024-12-23 to 2024-12-27, 2024-12-30 to 2025-01-03, 2025-01-06 to 2025-01-10, 2025-01-13 to 2025-01-17, 2025-01-20 to 2025-01-24, 2025-01-27 to 2025-01-31, 2025-02-03 to 2025-02-07, 2025-02-10 to 2025-02-14, 2025-02-17 to 2025-02-21, 2025-02-24 to 2025-02-28, 2025-03-03 to 2025-03-07, 2025-03-10 to 2025-03-14, 2025-03-17 to 2025-03-21, 2025-03-24 to 2025-03-28, 2025-03-31 to 2025-04-04, 2025-04-07 to 2025-04-11, 2025-04-14 to 2025-04-15, 2025-04-21, 2025-05-26, 2025-06-19, 2025-07-04.
- Cal12A-Paving 5d/12hol-Mjr Rdwy: Mon-Fri 08:00-16:00; Sat-Sun off. Exceptions (off unless hours are given): 2023-01-02, 2023-01-16, 2023-02-20, 2023-04-17, 2023-05-12, 2023-05-26, 2023-05-29, 2023-06-19, 2023-07-03 to 2023-07-04, 2023-09-01, 2023-09-04, 2023-10-06, 2023-10-09, 2023-11-15 to 2023-11-17, 2023-11-20 to 2023-11-24, 2023-11-27 to 2023-12-01, 2023-12-04 to 2023-12-08, 2023-12-11 to 2023-12-15, 2023-12-18 to 2023-12-22, 2023-12-25 to 2023-12-29, 2024-01-01 to 2024-01-05, 2024-01-08 to 2024-01-12, 2024-01-15 to 2024-01-19, 2024-01-22 to 2024-01-26, 2024-01-29 to 2024-02-02, 2024-02-05 to 2024-02-09, 2024-02-12 to 2024-02-16, 2024-02-19 to 2024-02-23, 2024-02-26 to 2024-03-01, 2024-03-04 to 2024-03-08, 2024-03-11 to 2024-03-15, 2024-03-18 to 2024-03-22, 2024-03-25 to 2024-03-29, 2024-04-15, 2024-05-10, 2024-05-24, 2024-05-27, 2024-06-19, 2024-07-03 to 2024-07-04, 2024-08-30, 2024-09-02, 2024-10-11, 2024-10-14, 2024-11-11, 2024-11-15, 2024-11-18 to 2024-11-22, 2024-11-25 to 2024-11-29, 2024-12-02 to 2024-12-06, 2024-12-09 to 2024-12-13, 2024-12-16 to 2024-12-20, 2024-12-23 to 2024-12-27, 2024-12-30 to 2025-01-03, 2025-01-06 to 2025-01-10, 2025-01-13 to 2025-01-17, 2025-01-20 to 2025-01-24, 2025-01-27 to 2025-01-31, 2025-02-03 to 2025-02-07, 2025-02-10 to 2025-02-14, 2025-02-17 to 2025-02-21, 2025-02-24 to 2025-02-28, 2025-03-03 to 2025-03-07, 2025-03-10 to 2025-03-14, 2025-03-17 to 2025-03-21, 2025-03-24 to 2025-03-28, 2025-03-31, 2025-04-21, 2025-05-09, 2025-05-23, 2025-05-26, 2025-06-19, 2025-07-03 to 2025-07-04.
- Cal11A-Wntr Shut 5d/12hol-Mjr Rdwy: Mon-Fri 08:00-16:00; Sat-Sun off. Exceptions (off unless hours are given): 2023-01-02, 2023-01-16, 2023-02-20, 2023-04-17, 2023-05-12, 2023-05-26, 2023-05-29, 2023-06-19, 2023-07-03 to 2023-07-04, 2023-09-01, 2023-09-04, 2023-10-06, 2023-10-09, 2023-11-21 to 2023-11-24, 2023-12-01, 2023-12-04 to 2023-12-08, 2023-12-11 to 2023-12-15, 2023-12-18 to 2023-12-22, 2023-12-25 to 2023-12-29, 2024-01-01 to 2024-01-05, 2024-01-08 to 2024-01-12, 2024-01-15 to 2024-01-19, 2024-01-22 to 2024-01-26, 2024-01-29 to 2024-02-02, 2024-02-05 to 2024-02-09, 2024-02-12 to 2024-02-16, 2024-02-19 to 2024-02-23, 2024-02-26 to 2024-03-01, 2024-03-04 to 2024-03-08, 2024-03-11 to 2024-03-15, 2024-04-15, 2024-05-10, 2024-05-24, 2024-05-27, 2024-06-19, 2024-07-03 to 2024-07-04, 2024-08-30, 2024-09-02, 2024-10-11, 2024-10-14, 2024-11-11, 2024-11-26 to 2024-11-29, 2024-12-02 to 2024-12-06, 2024-12-09 to 2024-12-13, 2024-12-16 to 2024-12-20, 2024-12-23 to 2024-12-27, 2024-12-30 to 2025-01-03, 2025-01-06 to 2025-01-10, 2025-01-13 to 2025-01-17, 2025-01-20 to 2025-01-24, 2025-01-27 to 2025-01-31, 2025-02-03 to 2025-02-07, 2025-02-10 to 2025-02-14, 2025-02-17 to 2025-02-21, 2025-02-24 to 2025-02-28, 2025-03-03 to 2025-03-07, 2025-03-10 to 2025-03-14, 2025-04-21, 2025-05-09, 2025-05-23, 2025-05-26, 2025-06-19, 2025-07-03 to 2025-07-04.

## Resources

| Resource | Group |
| --- | --- |
| Electrician | labor |
| Laborer | labor |
| Foreman | labor |
| Bulldozer Type X | equipment |
| Bid Item Value | equipment |
| Steel Worker | labor |
| Operator | labor |
| Crane Type X | equipment |
| Excavator Type X | equipment |
| Paver Type X | equipment |
| Grader TypeX | equipment |
| Compactor Type X | equipment |

## Schedule

| ID | WBS | Activity | Type | Duration | Start | Finish | Predecessors | Total float | Free float | Constraint | Calendar | CST-SubPhase | CST-Responsibility | CST-Type | CST-Step | CST-Phase |
| --- | --- | --- | --- | --- | --- | --- | --- | --- | --- | --- | --- | --- | --- | --- | --- | --- |
|  | DB CCTD 1.0.1 | **Design-Build Contract Procurement** |  |  | 2023-01-03 | 2023-07-22 |  |  |  |  |  |  |  |  |  |  |
| ContractNo_Prelim |  | BTC Plans/Specs/Spec. Prov. accepted by MassDOT | milestone | 0d | 2023-01-03 | 2023-01-03 |  | 70d | 0d |  |  | GN | DOT | NA | NS | PR |
| ContractNo_Prelim10 |  | FHWA Review BTC Plans/Specs/Spec. Provisions |  | 30d | 2023-01-03 | 2023-02-01 | ContractNo_Prelim SS | 100d | 0d |  | Cal03A - 7d/8hr/No Holidays | GN | FED | NA | NS | PR |
| ContractNo_LOI |  | Advertise Request for Letters-of-Interest (LOI) | milestone | 0d | 2023-01-07 | 2023-01-07 |  | 6d | 0d |  | Cal19 - Saturday Only (Advert) | GN | DOT | NA | NS | PR |
| ContractNo_LOIP |  | Letters-of-Interest (LOI) Procurement |  | 40d | 2023-01-07 | 2023-02-15 | ContractNo_LOI SS | 37d | 0d |  | Cal03A - 7d/8hr/No Holidays | GN | DOT | NA | NS | PR |
| ContractNo_RFP20 |  | FHWA Concurrance to Advertise | milestone | 0d | 2023-02-01 | 2023-02-01 | ContractNo_Prelim10 FF | 70d | 46d |  |  | GN | FED | NA | NS | PR |
| ContractNo_LOID |  | Letters-of-Interest (LOI) Due | milestone | 0d | 2023-02-15 | 2023-02-15 | ContractNo_LOIP FF | 26d | 0d |  |  | GN | D-B | NA | NS | PR |
| ContractNo_RFQ |  | Issue Request for Qualifications (RFQ) | milestone | 0d | 2023-02-16 | 2023-02-16 | ContractNo_LOID | 26d | 0d |  |  | GN | DOT | NA | NS | PR |
| ContractNo_RFQP |  | Statement of Qualifications Prepared |  | 28d | 2023-02-16 | 2023-03-15 | ContractNo_RFQ SS | 37d | 0d |  | Cal03A - 7d/8hr/No Holidays | GN | D-B | NA | NS | PR |
| ContractNo_RFQD |  | Statement of Qualifications Due | milestone | 0d | 2023-03-15 | 2023-03-15 | ContractNo_RFQP FF | 26d | 0d |  |  | GN | D-B | NA | NS | PR |
| ContractNo_ShList |  | Shortlist of Proposers Selected/Notified |  | 20d | 2023-03-16 | 2023-04-04 | ContractNo_RFQD | 39d | 3d |  | Cal03A - 7d/8hr/No Holidays | GN | DOT | NA | NS | PR |
| ContractNo_RFP10 |  | Advertise Request for Proposals | milestone | 0d | 2023-04-08 | 2023-04-08 | ContractNo_ShList, ContractNo_RFP20 | 6d | 1d |  | Cal19 - Saturday Only (Advert) | GN | DOT | NA | NS | PR |
| ContractNo_RFP |  | Release Request for Proposals (RFP) | milestone | 0d | 2023-04-10 | 2023-04-10 | ContractNo_RFP10 SS | 26d | 0d |  |  | GN | DOT | NA | NS | PR |
| ContractNo_RFPP |  | Proposers Prepare Proposals |  | 43d | 2023-04-10 | 2023-05-22 | ContractNo_RFP SS | 37d | 0d |  | Cal03A - 7d/8hr/No Holidays | GN | D-B | NA | NS | PR |
| ContractNo_RFPP20 |  | Pre-Proposal Meeting |  | 1d | 2023-04-10 | 2023-04-10 | ContractNo_RFPP SS | 44d | 0d |  |  | GN | DOT | NA | NS | PR |
| ContractNo_RFPP30 |  | ATC Meetings |  | 3d | 2023-04-11 | 2023-04-13 | ContractNo_RFPP20 | 44d | 0d |  |  | GN | DOT | NA | NS | PR |
| ContractNo_RFPP50 |  | ATC Proposals Due |  | 1d | 2023-04-14 | 2023-04-14 | ContractNo_RFPP30 | 44d | 19d |  |  | GN | D-B | NA | NS | PR |
| ContractNo_RFPP40 |  | Final RFP Questions Due |  | 1d | 2023-05-15 | 2023-05-15 | ContractNo_RFPP30, ContractNo_RFPP50 | 25d | 0d | as late as possible |  | GN | D-B | NA | NS | PR |
| ContractNo_RFPP10 |  | Technical and Price Proposals Due | milestone | 0d | 2023-05-22 | 2023-05-22 | ContractNo_RFPP FF, ContractNo_RFPP40 FF+5d | 25d | 0d |  |  | GN | D-B | NA | NS | PR |
| ContractNo_RFPD00 |  | Oral Presentation of Design-Build Proposals |  | 2d | 2023-05-31 | 2023-06-01 | ContractNo_RFPP, ContractNo_RFPP10 FS+5d | 25d | 0d |  |  | GN | D-B | NA | NS | PR |
| ContractNo_RFPD10 |  | Scoring of Technical Proposals |  | 2d | 2023-06-02 | 2023-06-05 | ContractNo_RFPD00 | 25d | 0d |  |  | GN | DOT | NA | NS | PR |
| ContractNo_BID |  | Public Price Bid Opening | milestone | 0d | 2023-06-06 | 2023-06-06 | ContractNo_RFPD10 FF+1d | 25d | 0d |  |  | GN | DOT | NA | NS | PR |
| ContractNo_NOA |  | Issue Notice of Award\Project Start |  | 45d | 2023-06-08 | 2023-07-22 | ContractNo_BID FS+1d | 39d | 0d |  | Cal03A - 7d/8hr/No Holidays | GN | DOT | NA | NS | PR |
|  | 1 | **Milestones** |  |  | 2023-07-22 | 2025-07-08 |  |  |  |  |  |  |  |  |  |  |
|  | 1 | **General** |  |  | 2023-07-22 | 2025-07-08 |  |  |  |  |  |  |  |  |  |  |
| ContractNo_NTP |  | Issue Design-Builder Notice-to-Proceed (NTP) | milestone | 0d | 2023-07-22 | 2023-07-22 | ContractNo_NOA | 39.67d | 1.67d |  | Cal04-7d/24Hr/No Hol (Milestones) | GN | DOT | NA | NS | MS |
| ContractNo_AR01 |  | Access Restraint: Relocate Util before Bridge Demo | milestone | 0d | 2024-04-10 | 2024-04-10 | ContractNo_1030 FF, ContractNo_U430 | 97.87d | 81.87d |  | Cal04-7d/24Hr/No Hol (Milestones) | GN | D-B | NA | NS | MS |
| ContractNo_MS03 |  | MS#03 - Full Beneficial Use (FBU) | milestone | 0d | 2025-04-23 | 2025-04-23 | ContractNo_C320 FF, ContractNo_C885 FF, ContractNo_MS04 FF, ContractNo_1000 FF, ContractNo_U480 FF | 0.67d |  | finish on or before 2026-10-01 | Cal04-7d/24Hr/No Hol (Milestones) | GN | D-B | NA | NS | MS |
| ContractNo_MS04 |  | MS#04 - Perform Final Traffic Move | milestone | 0d | 2025-04-23 | 2025-04-23 | ContractNo_C885 FF | 0.67d | 0d |  | Cal04-7d/24Hr/No Hol (Milestones) | GN | D-B | NA | NS | MS |
| ContractNo_MS02 |  | MS#02 - Substantial Completion (SC) | milestone | 0d | 2025-05-22 | 2025-05-22 | ContractNo_C340 FF, ContractNo_C360 SF | 0.67d |  | finish on or before 2026-10-01 | Cal04-7d/24Hr/No Hol (Milestones) | GN | D-B | NA | NS | MS |
| ContractNo_MS01 |  | MS#01 - Field Completion (CFC) | milestone | 0d | 2025-07-08 | 2025-07-08 | ContractNo_C470, ContractNo_1020 FF, ContractNo_C330 FF | 0d |  | finish on or before 2026-11-15 | Cal04-7d/24Hr/No Hol (Milestones) | GN | D-B | NA | NS | MS |

| ID | WBS | Activity | Type | Duration | Start | Finish | Predecessors | Total float | Free float | Calendar | Preliminary Estimate (Dec-08) | Stored Baseline Start | Stored Actual Start | Stored Baseline Finish | ABP Proj ID | Health Indicator | CST-SubPhase | CST-Responsibility | CST-Type | CST-Step | CST-Phase |
| --- | --- | --- | --- | --- | --- | --- | --- | --- | --- | --- | --- | --- | --- | --- | --- | --- | --- | --- | --- | --- | --- |
|  | 2 | **Durations** |  |  | 2023-07-22 | 2025-07-08 |  |  |  |  |  |  |  |  |  |  |  |  |  |  |  |
| ContractNo_1000 |  | Construction Contract Duration (NTP to FBU) | level of effort | 641d | 2023-07-22 | 2025-04-23 | ContractNo_NTP SS | 0.67d | 0d | Cal04-7d/24Hr/No Hol (Milestones) | 2485791 | 2008-11-28 | 2008-11-28 | 2009-12-31 | 602349 | UDF_G3 | DU | NA | NA | NS | MS |
| ContractNo_1010 |  | Construction Contract Duration (NTP to SC) | level of effort | 670d | 2023-07-22 | 2025-05-22 | ContractNo_MS02 FF, ContractNo_NTP SS | 0.67d | 0d | Cal04-7d/24Hr/No Hol (Milestones) | 2485791 | 2008-11-28 | 2008-11-28 | 2009-12-31 | 602349 | UDF_G3 | DU | NA | NA | NS | MS |
| ContractNo_1020 |  | Construction Contract Duration (NTP to CFC) | level of effort | 717d | 2023-07-22 | 2025-07-08 | ContractNo_NTP SS | 0d |  | Cal04-7d/24Hr/No Hol (Milestones) |  |  |  |  |  |  | DU | NA | NA | NS | MS |
| ContractNo_1030 |  | Construction Contract Duration (NTP to AR01) | level of effort | 262.8d | 2023-07-22 | 2024-04-10 | ContractNo_NTP SS | 97.87d | 0d | Cal04-7d/24Hr/No Hol (Milestones) | 2485791 | 2008-11-28 | 2008-11-28 | 2009-12-31 | 602349 | UDF_G3 | DU | NA | NA | NS | MS |
|  | 2 | **Submittals & Procurements** |  |  | 2023-07-24 | 2024-12-05 |  |  |  |  |  |  |  |  |  |  |  |  |  |  |  |
|  | 1 | **Early Release Design Packages** |  |  | 2023-07-24 | 2024-10-17 |  |  |  |  |  |  |  |  |  |  |  |  |  |  |  |
|  | 3 | **Geotechnical Report** |  |  | 2023-07-24 | 2023-11-17 |  |  |  |  |  |  |  |  |  |  |  |  |  |  |  |
| ContractNo_2640 |  | Prepare & Submit Subsurface Investigation Plan |  | 10d | 2023-07-24 | 2023-08-04 | ContractNo_NTP SS | 363d | 0d |  |  |  |  |  |  |  | DE | D-B | DES | NS | PC |
| ContractNo_2660 |  | Review & Approve Subsurface Investigation Plan |  | 10d | 2023-08-05 | 2023-08-14 | ContractNo_2640 | 532d | 0d | Cal03A - 7d/8hr/No Holidays |  |  |  |  |  |  | DE | DOT | DES | NS | PC |
| ContractNo_2650 |  | Schedule/Perform Geotech Borings & Test Pits |  | 30d | 2023-08-15 | 2023-09-26 | ContractNo_2640, ContractNo_2660 | 362d | 0d |  |  |  |  |  |  |  | DE | D-B | DES | NS | PC |
| ContractNo_1680 |  | Prepare Geotechnical Report |  | 9d | 2023-09-27 | 2023-10-10 | ContractNo_NTP SS, ContractNo_2650 | 362d | 0d |  |  |  |  |  |  |  | DE | D-B | DES | NS | PC |
| ContractNo_1950 |  | Schedule & Conduct OTS Review - Geotechnical Report |  | 2d | 2023-10-11 | 2023-10-12 | ContractNo_1680 | 362d | 0d |  |  |  |  |  |  |  | DE | D-B | DES | NS | PC |
| ContractNo_1940 |  | Submit Geotechnical Report |  | 4d | 2023-10-13 | 2023-10-18 | ContractNo_1950 | 362d | 0d |  |  |  |  |  |  |  | DE | D-B | DES | NS | PC |
| ContractNo_2050 |  | Review & Approve Geotechnical Report |  | 30d | 2023-10-19 | 2023-11-17 | ContractNo_1940 | 552d | 20d | Cal03A - 7d/8hr/No Holidays |  |  |  |  |  |  | DE | DOT | DES | NS | PC |
|  | 1 | **Drilled Shafts** |  |  | 2023-10-19 | 2024-01-20 |  |  |  |  |  |  |  |  |  |  |  |  |  |  |  |
| ContractNo_1740 |  | Prepare Drilled Shafts Design |  | 10d | 2023-10-19 | 2023-11-01 | ContractNo_1940 | 362d | 0d |  |  |  |  |  |  |  | DE | D-B | DES | NS | PC |
| ContractNo_1990 |  | Schedule & Conduct OTS Review - Drilled Shafts Design |  | 1d | 2023-11-02 | 2023-11-02 | ContractNo_1740 | 362d | 0d |  |  |  |  |  |  |  | DE | D-B | DES | NS | PC |
| ContractNo_1980 |  | Submit Drilled Shafts Design |  | 3d | 2023-11-03 | 2023-11-07 | ContractNo_1990 | 362d | 0d |  |  |  |  |  |  |  | DE | D-B | DES | NS | PC |
| ContractNo_2060 |  | Review & Approve Drilled Shafts Design |  | 30d | 2023-11-08 | 2023-12-07 | ContractNo_1980 | 532d | 0d | Cal03A - 7d/8hr/No Holidays |  |  |  |  |  |  | DE | DOT | DES | NS | PC |
| ContractNo_1750 |  | Comment Resolution & Reissue Drilled Shafts Design |  | 10d | 2023-12-08 | 2023-12-21 | ContractNo_2060, ContractNo_2050 | 363d | 0d |  |  |  |  |  |  |  | DE | D-B | DES | NS | PC |
| ContractNo_1890 |  | Procure Drilled Shaft Casings |  | 30d | 2023-12-22 | 2024-01-20 | ContractNo_1750 | 535d |  | Cal03A - 7d/8hr/No Holidays |  |  |  |  |  |  | PR | D-B | PRO | NS | PC |
|  | 4 | **Substructure Rebar** |  |  | 2023-07-24 | 2024-01-29 |  |  |  |  |  |  |  |  |  |  |  |  |  |  |  |
| ContractNo_1780 |  | Prepare Early Release - Substructure Design |  | 90d | 2023-07-24 | 2023-11-29 | ContractNo_NTP SS | 359d | 0d |  |  |  |  |  |  |  | DE | D-B | DES | NS | PC |
| ContractNo_2010 |  | Schedule & Conduct OTS Review - Early Release - Substructure Design |  | 7d | 2023-11-30 | 2023-12-08 | ContractNo_1780 | 359d | 0d |  |  |  |  |  |  |  | DE | D-B | DES | NS | PC |
| ContractNo_2000 |  | Submit Early Release - Substructure Design |  | 4d | 2023-12-11 | 2023-12-14 | ContractNo_2010 | 359d | 0d |  |  |  |  |  |  |  | DE | D-B | DES | NS | PC |
| ContractNo_2070 |  | Review & Approve Early Release - Substructure Design |  | 30d | 2023-12-15 | 2024-01-13 | ContractNo_2000 | 527d | 2d | Cal03A - 7d/8hr/No Holidays |  |  |  |  |  |  | DE | DOT | DES | NS | PC |
| ContractNo_1790 |  | Comment Resolution & Reissue Early Release - Substructure Design |  | 10d | 2024-01-16 | 2024-01-29 | ContractNo_2070 | 359d |  |  |  |  |  |  |  |  | DE | D-B | DES | NS | PC |

| ID | WBS | Activity | Duration | Start | Finish | Predecessors | Total float | Free float | Calendar | CST-SubPhase | CST-Responsibility | CST-Type | CST-Step | CST-Phase |
| --- | --- | --- | --- | --- | --- | --- | --- | --- | --- | --- | --- | --- | --- | --- |
|  | 2 | **Structural Steel** |  | 2023-07-24 | 2024-10-17 |  |  |  |  |  |  |  |  |  |
| ContractNo_1760 |  | Prepare Early Release - Superstructure Design | 90d | 2023-07-24 | 2023-11-29 | ContractNo_NTP SS | 28d | 0d |  | DE | D-B | DES | STL | PC |
| ContractNo_1970 |  | Schedule & Conduct OTS Review - Early Release - Superstructure Design | 1d | 2023-11-30 | 2023-11-30 | ContractNo_1760, ContractNo_1700, ContractNo_1820 | 28d | 0d |  | DE | D-B | DES | STL | PC |
| ContractNo_1960 |  | Submit Early Release - Superstructure Design | 1d | 2023-12-01 | 2023-12-01 | ContractNo_1700, ContractNo_1970 | 28d | 0d |  | DE | D-B | DES | STL | PC |
| ContractNo_1770 |  | Review & Approve Early Release - Superstructure Design | 30d | 2023-12-02 | 2023-12-31 | ContractNo_1760, ContractNo_1960 | 42d | 1d | Cal03A - 7d/8hr/No Holidays | DE | DOT | DES | STL | PC |
| ContractNo_2040 |  | Comment Resolution & Reissue Early Release - Superstructure Design | 5d | 2024-01-02 | 2024-01-08 | ContractNo_1770 | 28d | 0d |  | DE | D-B | DES | STL | PC |
| ContractNo_1710 |  | Prepare & Submit Structural Steel Shop Drawings | 40d | 2024-01-09 | 2024-03-06 | ContractNo_1770, ContractNo_2040 | 28d | 0d |  | DE | D-B | DES | STL | PC |
| ContractNo_1720 |  | Review & Approve Structural Steel Shop Drawings | 30d | 2024-03-07 | 2024-04-05 | ContractNo_1710 | 41d | 0d | Cal03A - 7d/8hr/No Holidays | DE | DOT | DES | STL | PC |
| ContractNo_1730 |  | Procure Structural Steel Stage 1 | 75d | 2024-04-06 | 2024-06-19 | ContractNo_1720 | 41d | 0d | Cal03A - 7d/8hr/No Holidays | PR | D-B | PRO | STL | PC |
| ContractNo_1800 |  | Procure Structural Steel Stage 2 | 120d | 2024-06-20 | 2024-10-17 | ContractNo_1730 | 264d |  | Cal03A - 7d/8hr/No Holidays | PR | D-B | PRO | STL | PC |
|  | 9 | **Bridge Bearings Design** |  | 2024-01-09 | 2024-03-07 |  |  |  |  |  |  |  |  |  |
| ContractNo_1830 |  | Prepare & Submit Early Release Bridge Bearings | 20d | 2024-01-09 | 2024-02-06 | ContractNo_2040 | 333d | 0d |  | DE | D-B | DES | NS | PC |
| ContractNo_1840 |  | Review & Approve Early Release Bridge Bearings | 30d | 2024-02-07 | 2024-03-07 | ContractNo_1830 | 488d |  | Cal03A - 7d/8hr/No Holidays | DE | DOT | DES | NS | PC |
|  | 10 | **Bridge Scuppers Design** |  | 2024-01-09 | 2024-04-12 |  |  |  |  |  |  |  |  |  |
| ContractNo_1850 |  | Prepare & Submit Bridge Scupper Design | 45d | 2024-01-09 | 2024-03-13 | ContractNo_2040 | 308d | 0d |  | DE | D-B | DES | NS | PC |
| ContractNo_1860 |  | Review & Approve Bridge Scupper Design | 30d | 2024-03-14 | 2024-04-12 | ContractNo_1850 | 452d |  | Cal03A - 7d/8hr/No Holidays | DE | DOT | DES | NS | PC |
|  | 11 | **Bridge Joint Design** |  | 2024-01-09 | 2024-04-12 |  |  |  |  |  |  |  |  |  |
| ContractNo_1870 |  | Prepare & Submit Bridge Joint Design | 45d | 2024-01-09 | 2024-03-13 | ContractNo_2040 | 308d | 0d |  | DE | D-B | DES | NS | PC |
| ContractNo_1880 |  | Review & Approve Bridge Joint Design | 30d | 2024-03-14 | 2024-04-12 | ContractNo_1870 | 452d |  | Cal03A - 7d/8hr/No Holidays | DE | DOT | DES | NS | PC |
|  | 2 | **Projectwide Submittals** |  | 2023-07-24 | 2024-01-04 |  |  |  |  |  |  |  |  |  |
|  | 1 | **Project Schedule** |  | 2023-07-24 | 2024-01-04 |  |  |  |  |  |  |  |  |  |
| ContractNo_2080 |  | Prepare & Submit Initial Baseline Project Schedule (Logic Only) | 40d | 2023-07-24 | 2023-09-18 | ContractNo_NTP SS, ContractNo_PCM2 SF+10d | 376d | 0d |  | GN | D-B | NA | BLS | PC |
| ContractNo_2090 |  | Review & Comment on Initial Baseline Project Schedule (Logic Only) | 30d | 2023-09-19 | 2023-10-18 | ContractNo_2080 | 551d | 0d | Cal03A - 7d/8hr/No Holidays | GN | DOT | NA | BLS | PC |
| ContractNo_2220 |  | Prepare & Submit Baseline Schedule (Logic Only) (Rev 1) | 15d | 2023-10-19 | 2023-11-08 | ContractNo_2090 | 375d | 0d |  | GN | D-B | NA | BLS | PC |
| ContractNo_2230 |  | Review & Comment on Baseline Schedule (Logic Only (Rev 1) | 15d | 2023-11-09 | 2023-11-23 | ContractNo_2220 | 551d | 0d | Cal03A - 7d/8hr/No Holidays | GN | DOT | NA | BLS | PC |
| ContractNo_2620 |  | Prepare & Submit Cost & Resource Loaded Baseline Schedule | 15d | 2023-11-24 | 2023-12-14 | ContractNo_2230 | 375d | 0d |  | GN | D-B | NA | BLS | PC |
| ContractNo_2630 |  | Review & Approve Cost & Resource Loaded Baseline Schedule | 21d | 2023-12-15 | 2024-01-04 | ContractNo_2620 | 551d |  | Cal03A - 7d/8hr/No Holidays | GN | DOT | NA | BLS | PC |

| ID | WBS | Activity | Duration | Start | Finish | Predecessors | Total float | Free float | Calendar | CST-SubPhase | CST-Responsibility | CST-Type | CST-Step | CST-Phase |
| --- | --- | --- | --- | --- | --- | --- | --- | --- | --- | --- | --- | --- | --- | --- |
|  | 2 | **Project Management Plan** |  | 2023-07-24 | 2023-10-01 |  |  |  |  |  |  |  |  |  |
| ContractNo_2100 |  | Prepare & Submit Project Management Plan | 30d | 2023-07-24 | 2023-09-01 | ContractNo_NTP SS | 439d | 0d |  | GN | D-B | NA | NS | PC |
| ContractNo_2110 |  | Review & Approve Project Management Plan | 30d | 2023-09-02 | 2023-10-01 | ContractNo_2100 | 646d |  | Cal03A - 7d/8hr/No Holidays | GN | DOT | NA | NS | PC |
|  | 4 | **Public Participation Plan** |  | 2023-07-24 | 2023-10-01 |  |  |  |  |  |  |  |  |  |
| ContractNo_2120 |  | Prepare & Submit Public Participation Plan | 30d | 2023-07-24 | 2023-09-01 | ContractNo_NTP SS | 439d | 0d |  | GN | D-B | NA | NS | PC |
| ContractNo_2160 |  | Setup Project Webpage | 20d | 2023-07-24 | 2023-08-18 | ContractNo_NTP SS | 469d |  |  | GN | D-B | NA | NS | PC |
| ContractNo_2130 |  | Review & Approve Public Participation Plan | 30d | 2023-09-02 | 2023-10-01 | ContractNo_2120 | 646d |  | Cal03A - 7d/8hr/No Holidays | GN | DOT | NA | NS | PC |
|  | 5 | **Health & Safety Plan** |  | 2023-07-24 | 2023-09-17 |  |  |  |  |  |  |  |  |  |
| ContractNo_2140 |  | Prepare & Submit Health & Safety Plan | 20d | 2023-07-24 | 2023-08-18 | ContractNo_NTP SS | 449d | 0d |  | GN | D-B | NA | NS | PC |
| ContractNo_2150 |  | Review & Approve Health & Safety Plan | 30d | 2023-08-19 | 2023-09-17 | ContractNo_2140 | 660d |  | Cal03A - 7d/8hr/No Holidays | GN | DOT | NA | NS | PC |
|  | 3 | **Environmental Submittals** |  | 2023-07-24 | 2023-12-29 |  |  |  |  |  |  |  |  |  |
|  | 8 | **Groundwater & Soil Management Plan** |  | 2023-07-24 | 2023-10-25 |  |  |  |  |  |  |  |  |  |
| ContractNo_2520 |  | Prepare & Submit Groundwater & Soil Management Plan | 45d | 2023-07-24 | 2023-09-25 | ContractNo_NTP SS | 167d | 0d |  | DE | D-B | DES | NS | PC |
| ContractNo_2530 |  | Review & Approve Groundwater & Soil Management Plan | 30d | 2023-09-26 | 2023-10-25 | ContractNo_2520 | 244d | 228d | Cal03A - 7d/8hr/No Holidays | DE | DOT | DES | NS | PC |
|  | 10 | **Noise Control Plan** |  | 2023-07-24 | 2023-10-01 |  |  |  |  |  |  |  |  |  |
| ContractNo_2540 |  | Prepare & Submit Noise Control Plan | 30d | 2023-07-24 | 2023-09-01 | ContractNo_NTP SS | 439d | 0d |  | DE | D-B | DES | NS | PC |
| ContractNo_2550 |  | Review & Approve Noise Control Plan | 30d | 2023-09-02 | 2023-10-01 | ContractNo_2540 | 646d |  | Cal03A - 7d/8hr/No Holidays | DE | DOT | DES | NS | PC |
|  | 11 | **Dust Control Plan** |  | 2023-07-24 | 2023-10-01 |  |  |  |  |  |  |  |  |  |
| ContractNo_2560 |  | Prepare & Submit Dust Control Plan | 30d | 2023-07-24 | 2023-09-01 | ContractNo_NTP SS | 439d | 0d |  | DE | D-B | DES | NS | PC |
| ContractNo_2570 |  | Review & Approve Dust Control Plan | 30d | 2023-09-02 | 2023-10-01 | ContractNo_2560 | 646d |  | Cal03A - 7d/8hr/No Holidays | DE | DOT | DES | NS | PC |
|  | 13 | **Invasive Species Management Plan** |  | 2023-07-24 | 2023-10-18 |  |  |  |  |  |  |  |  |  |
| ContractNo_2600 |  | Prepare & Submit Invasive Species Management Plan | 40d | 2023-07-24 | 2023-09-18 | ContractNo_NTP SS | 429d | 0d |  | DE | D-B | DES | NS | PC |
| ContractNo_2610 |  | Review & Approve Invasive Species Management Plan | 30d | 2023-09-19 | 2023-10-18 | ContractNo_2600 | 629d |  | Cal03A - 7d/8hr/No Holidays | DE | DOT | DES | NS | PC |
|  | 12 | **Dredge Material Plan** |  | 2023-07-24 | 2023-12-29 |  |  |  |  |  |  |  |  |  |
| ContractNo_2580 |  | Prepare & Submit Dredge Material Plan | 90d | 2023-07-24 | 2023-11-29 | ContractNo_NTP SS | 379d | 0d |  | DE | D-B | DES | NS | PC |
| ContractNo_2590 |  | Review & Approve Dredge Material Plan | 30d | 2023-11-30 | 2023-12-29 | ContractNo_2580 | 557d |  | Cal03A - 7d/8hr/No Holidays | DE | DOT | DES | NS | PC |

| ID | WBS | Activity | Duration | Start | Finish | Predecessors | Total float | Free float | Calendar | CST-SubPhase | CST-Responsibility | CST-Type | CST-Step | CST-Phase |
| --- | --- | --- | --- | --- | --- | --- | --- | --- | --- | --- | --- | --- | --- | --- |
|  | 4 | **Design Submittals** |  | 2023-07-24 | 2024-12-05 |  |  |  |  |  |  |  |  |  |
|  | 1 | **Formal Bridge Sketch Plan** |  | 2023-07-24 | 2023-11-02 |  |  |  |  |  |  |  |  |  |
| ContractNo_1690 |  | Prepare Formal Bridge Sketch Plan | 35d | 2023-07-24 | 2023-09-11 | ContractNo_NTP SS | 46d | 0d |  | DE | D-B | DES | NS | PC |
| ContractNo_1930 |  | Schedule & Conduct OTS Review - Formal Bridge Sketch Plan | 2d | 2023-09-12 | 2023-09-13 | ContractNo_1690 | 46d | 0d |  | DE | D-B | DES | NS | PC |
| ContractNo_1920 |  | Submit Formal Bridge Sketch Plan | 4d | 2023-09-14 | 2023-09-19 | ContractNo_1930 | 46d | 0d |  | DE | D-B | DES | NS | PC |
| ContractNo_2020 |  | Review & Approve Formal Bridge Sketch Plan | 30d | 2023-09-20 | 2023-10-19 | ContractNo_1920 | 68d | 0d | Cal03A - 7d/8hr/No Holidays | DE | DOT | DES | NS | PC |
| ContractNo_1700 |  | Comment Resolution & Reissue Formal Bridge Sketch Plan | 10d | 2023-10-20 | 2023-11-02 | ContractNo_1920, ContractNo_2020 | 46d | 18d |  | DE | D-B | DES | NS | PC |
|  | 2 | **First Structural Design - Bridge** |  | 2023-10-20 | 2024-02-02 |  |  |  |  |  |  |  |  |  |
| ContractNo_2670 |  | Prepare First Structural Bridge | 37d | 2023-10-20 | 2023-12-12 | ContractNo_2020 | 142d | 0d |  | DE | D-B | DES | NS | PC |
| ContractNo_2770 |  | Schedule & Conduct OTS Review - First Structural Bridge | 2d | 2023-12-13 | 2023-12-14 | ContractNo_2670 | 142d | 0d |  | DE | D-B | DES | NS | PC |
| ContractNo_2780 |  | Finalize First Structural Bridge | 2d | 2023-12-15 | 2023-12-18 | ContractNo_2770 | 142d | 0d |  | DE | D-B | DES | NS | PC |
| ContractNo_2790 |  | Formal QC Review First Structural Bridge | 3d | 2023-12-19 | 2023-12-21 | ContractNo_2780 | 142d | 0d |  | DE | D-B | DES | NS | PC |
| ContractNo_2800 |  | Submit First Structural Bridge | 1d | 2023-12-22 | 2023-12-22 | ContractNo_2790 | 142d | 0d |  | DE | D-B | DES | NS | PC |
| ContractNo_2970 |  | Review & Approve First Structural Bridge | 30d | 2023-12-23 | 2024-01-21 | ContractNo_2800 | 211d | 0d | Cal03A - 7d/8hr/No Holidays | DE | DOT | DES | NS | PC |
| ContractNo_2680 |  | Comment Resolution & Reissue First Structural Bridge | 10d | 2024-01-22 | 2024-02-02 | ContractNo_2970 | 146d | 0d |  | DE | D-B | DES | NS | PC |
|  | 5 | **Second Structural Design - Bridge** |  | 2024-02-05 | 2024-04-05 |  |  |  |  |  |  |  |  |  |
| ContractNo_2710 |  | Prepare Second Structural Bridge | 5d | 2024-02-05 | 2024-02-09 | ContractNo_2680 | 274d | 0d |  | DE | D-B | DES | NS | PC |
| ContractNo_2850 |  | Schedule & Conduct OTS Review - Second Structural Bridge | 2d | 2024-02-12 | 2024-02-13 | ContractNo_2710 | 274d | 0d |  | DE | D-B | DES | NS | PC |
| ContractNo_2860 |  | Finalize Second Structural Bridge | 2d | 2024-02-14 | 2024-02-15 | ContractNo_2850 | 274d | 0d |  | DE | D-B | DES | NS | PC |
| ContractNo_2870 |  | Formal QC Review Second Structural Bridge | 3d | 2024-02-16 | 2024-02-21 | ContractNo_2860 | 274d | 0d |  | DE | D-B | DES | NS | PC |
| ContractNo_2880 |  | Submit Second Structural Bridge | 1d | 2024-02-22 | 2024-02-22 | ContractNo_2870 | 274d | 0d |  | DE | D-B | DES | NS | PC |
| ContractNo_2990 |  | Review & Approve Second Structural Bridge | 30d | 2024-02-23 | 2024-03-23 | ContractNo_2880 | 402d | 1d | Cal03A - 7d/8hr/No Holidays | DE | DOT | DES | NS | PC |
| ContractNo_2720 |  | Comment Resolution & Reissue Second Structural Bridge | 10d | 2024-03-25 | 2024-04-05 | ContractNo_2710, ContractNo_2880, ContractNo_2990 | 274d | 129d |  | DE | D-B | DES | NS | PC |
|  | 4 | **75% Design - Highway** |  | 2024-02-05 | 2024-07-19 |  |  |  |  |  |  |  |  |  |
| ContractNo_2690 |  | Prepare 75% Design - Highway | 75d | 2024-02-05 | 2024-05-21 | ContractNo_2680 | 146d | 0d |  | DE | D-B | DES | NS | PC |
| ContractNo_2810 |  | Schedule & Conduct OTS Review - 75% Design - Highway | 2d | 2024-05-22 | 2024-05-23 | ContractNo_2690 | 146d | 0d |  | DE | D-B | DES | NS | PC |
| ContractNo_2820 |  | Finalize 75% Design - Highway | 2d | 2024-05-24 | 2024-05-28 | ContractNo_2810 | 146d | 0d |  | DE | D-B | DES | NS | PC |
| ContractNo_2830 |  | Formal QC Review 75% Design - Highway | 3d | 2024-05-29 | 2024-05-31 | ContractNo_2820 | 146d | 0d |  | DE | D-B | DES | NS | PC |
| ContractNo_2840 |  | Submit 75% Design - Highway | 1d | 2024-06-03 | 2024-06-03 | ContractNo_2830 | 146d | 0d |  | DE | D-B | DES | NS | PC |
| ContractNo_2980 |  | Review & Approve 75% Design - Highway | 30d | 2024-06-04 | 2024-07-03 | ContractNo_2840 | 215d | 1d | Cal03A - 7d/8hr/No Holidays | DE | DOT | DES | NS | PC |
| ContractNo_2700 |  | Comment Resolution & Reissue 75% Design - Highway | 10d | 2024-07-05 | 2024-07-18 | ContractNo_2690, ContractNo_2980 | 145d | 0d |  | DE | D-B | DES | NS | PC |
| ContractNo_3570 |  | Submit 75% Design - Highway - REV1 (15 Days if required) | 0d | 2024-07-19 | 2024-07-19 | ContractNo_2700 | 145d | 0d |  | DE | D-B | DES | NS | PC |
| ContractNo_3580 |  | Review & Approve 75% Design - Highway - REV-1 (30 Days if required) | 0d | 2024-07-19 | 2024-07-19 | ContractNo_3570 | 215d | 0d | Cal03A - 7d/8hr/No Holidays | DE | DOT | DES | NS | PC |

| ID | WBS | Activity | Duration | Start | Finish | Predecessors | Total float | Free float | Calendar | CST-SubPhase | CST-Responsibility | CST-Type | CST-Step | CST-Phase |
| --- | --- | --- | --- | --- | --- | --- | --- | --- | --- | --- | --- | --- | --- | --- |
|  | 3 | **100% Design - Highway** |  | 2024-07-19 | 2024-10-10 |  |  |  |  |  |  |  |  |  |
| ContractNo_2750 |  | Prepare 100% Design - Highway | 20d | 2024-07-19 | 2024-08-15 | ContractNo_3580 | 145d | 0d |  | DE | D-B | DES | NS | PC |
| ContractNo_2890 |  | Schedule & Conduct OTS Review - 100% Design - Highway | 2d | 2024-08-16 | 2024-08-19 | ContractNo_2750 | 145d | 0d |  | DE | D-B | DES | NS | PC |
| ContractNo_2900 |  | Finalize 100% Design - Highway | 2d | 2024-08-20 | 2024-08-21 | ContractNo_2890 | 145d | 0d |  | DE | D-B | DES | NS | PC |
| ContractNo_2910 |  | Formal QC Review 100% Design - Highway | 3d | 2024-08-22 | 2024-08-26 | ContractNo_2900 | 145d | 0d |  | DE | D-B | DES | NS | PC |
| ContractNo_2920 |  | Submit 100% Design - Highway | 1d | 2024-08-27 | 2024-08-27 | ContractNo_2910 | 145d | 0d |  | DE | D-B | DES | NS | PC |
| ContractNo_3000 |  | Review & Approve 100% Design - Highway (MassDOT) | 30d | 2024-08-28 | 2024-09-26 | ContractNo_2920 | 215d | 0d | Cal03A - 7d/8hr/No Holidays | DE | DOT | DES | NS | PC |
| ContractNo_2760 |  | Comment Resolution & Reissue 100% Design - Highway | 10d | 2024-09-27 | 2024-10-10 | ContractNo_2750, ContractNo_2920, ContractNo_3000 | 145d | 0d |  | DE | D-B | DES | NS | PC |
|  | 7 | **Final Design - Bridge & Highway** |  | 2024-10-11 | 2024-12-05 |  |  |  |  |  |  |  |  |  |
| ContractNo_2730 |  | Prepare "RFC" Final Design - Bridge & Highway | 9d | 2024-10-11 | 2024-10-24 | ContractNo_2720, ContractNo_2760 | 145d | 0d |  | DE | D-B | DES | NS | PC |
| ContractNo_2930 |  | Schedule & Conduct OTS Review - "RFC" Final Design - Bridge & Highway | 2d | 2024-10-25 | 2024-10-28 | ContractNo_2730 | 145d | 0d |  | DE | D-B | DES | NS | PC |
| ContractNo_2940 |  | Finalize "RFC" Final Design - Bridge & Highway | 2d | 2024-10-29 | 2024-10-30 | ContractNo_2930 | 145d | 0d |  | DE | D-B | DES | NS | PC |
| ContractNo_2950 |  | Formal QC Review "RFC" Final Design - Bridge & Highway | 3d | 2024-10-31 | 2024-11-04 | ContractNo_2940 | 145d | 0d |  | DE | D-B | DES | NS | PC |
| ContractNo_2960 |  | Submit "RFC" Final Design - Bridge & Highway | 1d | 2024-11-05 | 2024-11-05 | ContractNo_2950 | 145d | 0d |  | DE | D-B | DES | NS | PC |
| ContractNo_2740 |  | Review & Approve "RFC" Final Design - Bridge & Highway (MassDOT) | 30d | 2024-11-06 | 2024-12-05 | ContractNo_2730, ContractNo_2960 | 215d |  | Cal03A - 7d/8hr/No Holidays | DE | DOT | DES | NS | PC |
|  | 5 | **Early Action Construction Submittals** |  | 2023-07-24 | 2023-11-01 |  |  |  |  |  |  |  |  |  |
|  | 5 | **RTTM** |  | 2023-07-24 | 2023-11-01 |  |  |  |  |  |  |  |  |  |
| ContractNo_1470 |  | Prepare & Submit RTTM System | 20d | 2023-07-24 | 2023-08-18 | ContractNo_NTP SS | 45.6d | 0d |  | DE | D-B | DES | NS | PC |
| ContractNo_1540 |  | Review & Approve RTTM System | 30d | 2023-08-19 | 2023-09-17 | ContractNo_1470 | 67.6d | 0d | Cal03A - 7d/8hr/No Holidays | DE | DOT | DES | NS | PC |
| ContractNo_1480 |  | Comment Resolution & Reissue RTTM System | 10.4d | 2023-09-18 | 2023-10-02 | ContractNo_1470, ContractNo_1540 | 47.6d | 0d |  | DE | D-B | DES | NS | PC |
| ContractNo_1490 |  | Procure RTTM System | 30d | 2023-10-02 | 2023-11-01 | ContractNo_1480 | 69.6d | 0d | Cal03A - 7d/8hr/No Holidays | PR | D-B | PRO | NS | PC |
|  | 1 | **Quality Management Plan (QMP)** |  | 2023-07-24 | 2023-09-17 |  |  |  |  |  |  |  |  |  |
| ContractNo_1040 |  | Prepare & Submit Quality Management Plan | 20d | 2023-07-24 | 2023-08-18 | ContractNo_NTP SS | 449d | 0d |  | DE | D-B | DES | NS | PC |
| ContractNo_1050 |  | Review & Approve Quality Management Plan | 30d | 2023-08-19 | 2023-09-17 | ContractNo_1040 | 660d |  | Cal03A - 7d/8hr/No Holidays | DE | DOT | DES | NS | PC |

| ID | WBS | Activity | Duration | Start | Finish | Predecessors | Total float | Free float | Calendar | CST-SubPhase | CST-Responsibility | CST-Type | CST-Step | CST-Phase | Note - Internal |
| --- | --- | --- | --- | --- | --- | --- | --- | --- | --- | --- | --- | --- | --- | --- | --- |
|  | 7 | **Bathymetric Survey** |  | 2023-07-24 | 2023-08-15 |  |  |  |  |  |  |  |  |  |  |
| ContractNo_1360 |  | Schedule & Conduct Bathymetric Survey | 7d | 2023-07-24 | 2023-08-01 | ContractNo_NTP SS | 452d | 0d |  | DE | D-B | DES | NS | PC |  |
| ContractNo_1370 |  | Prepare & Submit Bathymetric Survey Report | 10d | 2023-08-02 | 2023-08-15 | ContractNo_1360 | 452d | 0d |  | DE | D-B | DES | NS | PC | Start ASAP |
|  | 3 | **Final Hydraulic & Scour Analysis Report** |  | 2023-08-16 | 2023-09-13 |  |  |  |  |  |  |  |  |  |  |
| ContractNo_1380 |  | Prepare & Submit Final Hydraulic & Scour Analysis Report | 20d | 2023-08-16 | 2023-09-13 | ContractNo_1370 | 452d |  |  | DE | D-B | DES | NS | PC | End 9/3 |
|  | 2 | **Temporary Trestle Design** |  | 2023-07-24 | 2023-10-19 |  |  |  |  |  |  |  |  |  |  |
| ContractNo_1390 |  | Prepare & Submit Temporary Trestle Design | 17d | 2023-07-24 | 2023-08-15 | ContractNo_NTP SS | 428.6d | 0d |  | DE | D-B | DES | NS | PC |  |
| ContractNo_1510 |  | Review & Approve Temporary Trestle | 30d | 2023-08-16 | 2023-09-14 | ContractNo_1390 | 628.6d | 0d | Cal03A - 7d/8hr/No Holidays | DE | DOT | DES | NS | PC |  |
| ContractNo_1400 |  | Comment Resolution & Reissue Temporary Trestle Design | 10.4d | 2023-09-15 | 2023-09-29 | ContractNo_1510 | 428.6d | 0d |  | DE | D-B | DES | NS | PC |  |
| ContractNo_1410 |  | Procure Temporary Trestle | 20d | 2023-09-29 | 2023-10-19 | ContractNo_1400 | 628.6d |  | Cal03A - 7d/8hr/No Holidays | PR | D-B | PRO | NS | PC |  |
|  | 6 | **Support of Excavation Design** |  | 2023-07-24 | 2023-10-21 |  |  |  |  |  |  |  |  |  |  |
| ContractNo_1610 |  | Prepare & Submit Support of Excavation Design | 30d | 2023-07-24 | 2023-09-01 | ContractNo_NTP SS | 427d | 0d |  | DE | D-B | DES | NS | PC |  |
| ContractNo_1620 |  | Review & Approve Support of Excavation Design | 30d | 2023-09-02 | 2023-10-01 | ContractNo_1610 | 627d | 0d | Cal03A - 7d/8hr/No Holidays | DE | DOT | DES | NS | PC |  |
| ContractNo_1630 |  | Comment Resolution & Reissue Support of Excavation Design | 10d | 2023-10-02 | 2023-10-16 | ContractNo_1620 | 428d | 0d |  | DE | D-B | DES | NS | PC |  |
| ContractNo_1500 |  | Procure Support of Excavation | 5d | 2023-10-17 | 2023-10-21 | ContractNo_1630, ContractNo_1620 | 626d |  | Cal03A - 7d/8hr/No Holidays | PR | D-B | PRO | NS | PC |  |
|  | 4 | **Existing Sewer Line Protection Plan** |  | 2023-07-24 | 2023-09-29 |  |  |  |  |  |  |  |  |  |  |
| ContractNo_1420 |  | Prepare & Submit Existing Sewer Line Protection Plan | 19d | 2023-07-24 | 2023-08-17 | ContractNo_NTP SS | 441d | 0d |  | DE | D-B | DES | NS | PC |  |
| ContractNo_1520 |  | Review & Approve Existing Sewer Line Protection Plan | 30d | 2023-08-18 | 2023-09-16 | ContractNo_1420 | 646d | 1d | Cal03A - 7d/8hr/No Holidays | DE | DOT | DES | NS | PC |  |
| ContractNo_1430 |  | Comment Resolution & Reissue Existing Sewer Line Protection Plan | 10d | 2023-09-01 | 2023-09-18 | ContractNo_1420, ContractNo_1520 FF | 440d | 0d |  | DE | D-B | DES | NS | PC |  |
| ContractNo_1460 |  | Conduct CCTV Inspection of Existing Sanitary Sewer & Submit Report | 10d | 2023-09-18 | 2023-09-29 | ContractNo_1430, ContractNo_1520 | 440d |  |  | DE | D-B | DES | NS | PC |  |
|  | 9 | **Stormwater Management Plan** |  | 2023-07-24 | 2023-09-19 |  |  |  |  |  |  |  |  |  |  |
| ContractNo_1440 |  | Prepare & Submit Stormwater Management Plan | 5d | 2023-07-24 | 2023-07-28 | ContractNo_NTP SS | 192d | 0d |  | DE | D-B | DES | NS | PC |  |
| ContractNo_1560 |  | Schedule & Conduct Over the Shoulder - Stormwater Management Plan | 5d | 2023-07-31 | 2023-08-04 | ContractNo_1440 | 192d | 0d |  | DE | D-B | DES | NS | PC |  |
| ContractNo_1530 |  | Review & Approve Stormwater Management Plan | 30d | 2023-08-05 | 2023-09-03 | ContractNo_1440, ContractNo_1560 | 281d | 1d | Cal03A - 7d/8hr/No Holidays | DE | DOT | DES | NS | PC |  |
| ContractNo_1450 |  | Comment Resolution & Reissue Stormwater Management Plan | 10.4d | 2023-09-05 | 2023-09-19 | ContractNo_1440, ContractNo_1530 | 448.6d |  |  | DE | D-B | DES | NS | PC |  |

| ID | WBS | Activity | Duration | Start | Finish | Predecessors | Total float | Free float | Calendar | CST-SubPhase | CST-Responsibility | CST-Type | CST-Step | CST-Phase |
| --- | --- | --- | --- | --- | --- | --- | --- | --- | --- | --- | --- | --- | --- | --- |
|  | 12 | **Geotechnical Instrumentation & Monitoring Plan** |  | 2023-07-24 | 2023-09-29 |  |  |  |  |  |  |  |  |  |
| ContractNo_1580 |  | Prepare & Submit Geotechnical Instrumentation & Monitoring Plan | 20d | 2023-07-24 | 2023-08-18 | ContractNo_NTP SS | 440d | 0d |  | DE | D-B | DES | NS | PC |
| ContractNo_1590 |  | Review & Approve Geotechnical Instrumentation & Monitoring Plan | 30d | 2023-08-19 | 2023-09-17 | ContractNo_1580 | 645d | 0d | Cal03A - 7d/8hr/No Holidays | DE | DOT | DES | NS | PC |
| ContractNo_1600 |  | Install Geotechnical & Monitoring Instrumentation | 10d | 2023-09-18 | 2023-09-29 | ContractNo_1590 | 440d |  |  | DE | D-B | DES | NS | PC |
|  | 6 | **Quality Control Plans** |  | 2023-07-24 | 2023-10-18 |  |  |  |  |  |  |  |  |  |
|  | 1 | **Drilled Shaft Quality Control Plan** |  | 2023-07-24 | 2023-10-18 |  |  |  |  |  |  |  |  |  |
| ContractNo_2400 |  | Prepare & Submit Drilled Shaft Quality Control Plan | 40d | 2023-07-24 | 2023-09-18 | ContractNo_NTP SS | 429d | 0d |  | DE | D-B | DES | NS | PC |
| ContractNo_2410 |  | Review & Approve Drilled Shaft Quality Control Plan | 30d | 2023-09-19 | 2023-10-18 | ContractNo_2400 | 629d |  | Cal03A - 7d/8hr/No Holidays | DE | DOT | DES | NS | PC |
|  | 2 | **Deck Membrane Waterproofing** |  | 2023-07-24 | 2023-10-18 |  |  |  |  |  |  |  |  |  |
| ContractNo_2420 |  | Prepare & Submit Deck Membrane Waterproofing Quality Control Plan | 40d | 2023-07-24 | 2023-09-18 | ContractNo_NTP SS | 429d | 0d |  | DE | D-B | DES | NS | PC |
| ContractNo_2430 |  | Review & Approve Deck Membrane Waterproofing Quality Control Plan | 30d | 2023-09-19 | 2023-10-18 | ContractNo_2420 | 629d |  | Cal03A - 7d/8hr/No Holidays | DE | DOT | DES | NS | PC |
|  | 3 | **Earthwork** |  | 2023-07-24 | 2023-10-18 |  |  |  |  |  |  |  |  |  |
| ContractNo_2440 |  | Prepare & Submit Earthwork Quality Control Plan | 40d | 2023-07-24 | 2023-09-18 | ContractNo_NTP SS | 429d | 0d |  | DE | D-B | DES | NS | PC |
| ContractNo_2450 |  | Review & Approve Earthwork Quality Control Plan | 30d | 2023-09-19 | 2023-10-18 | ContractNo_2440 | 629d |  | Cal03A - 7d/8hr/No Holidays | DE | DOT | DES | NS | PC |
|  | 4 | **HMA Pavement** |  | 2023-07-24 | 2023-10-18 |  |  |  |  |  |  |  |  |  |
| ContractNo_2460 |  | Prepare & Submit HMA Pavement Quality Control Plan | 40d | 2023-07-24 | 2023-09-18 | ContractNo_NTP SS | 429d | 0d |  | DE | D-B | DES | NS | PC |
| ContractNo_2470 |  | Review & Approve HMA Pavement Quality Control Plan | 30d | 2023-09-19 | 2023-10-18 | ContractNo_2460 | 629d |  | Cal03A - 7d/8hr/No Holidays | DE | DOT | DES | NS | PC |
|  | 5 | **Portland Cement Concrete - Cast in Place Elements** |  | 2023-07-24 | 2023-10-18 |  |  |  |  |  |  |  |  |  |
| ContractNo_2480 |  | Prepare & Submit Portland Cement Concrete - Cast in Place Elements Quality Control Plan | 40d | 2023-07-24 | 2023-09-18 | ContractNo_NTP SS | 429d | 0d |  | DE | D-B | DES | NS | PC |
| ContractNo_2490 |  | Review & Approve Portland Cement Concrete - Cast in Place Elements Quality Control Plan | 30d | 2023-09-19 | 2023-10-18 | ContractNo_2480 | 629d |  | Cal03A - 7d/8hr/No Holidays | DE | DOT | DES | NS | PC |
|  | 6 | **Structural Steel Element** |  | 2023-07-24 | 2023-10-18 |  |  |  |  |  |  |  |  |  |
| ContractNo_2500 |  | Prepare & Submit Structural Steel Element Quality Control Plan | 40d | 2023-07-24 | 2023-09-18 | ContractNo_NTP SS | 429d | 0d |  | DE | D-B | DES | NS | PC |
| ContractNo_2510 |  | Review & Approve Structural Steel Element Quality Control Plan | 30d | 2023-09-19 | 2023-10-18 | ContractNo_2500 | 629d |  | Cal03A - 7d/8hr/No Holidays | DE | DOT | DES | NS | PC |
|  | 7 | **Construction Submittals** |  | 2023-07-24 | 2024-03-15 |  |  |  |  |  |  |  |  |  |
|  | 2 | **Traffic Management Plan (TTCP)** |  | 2023-07-24 | 2023-11-02 |  |  |  |  |  |  |  |  |  |
| ContractNo_1900 |  | Prepare Traffic Management Plan (Stage 1) | 35d | 2023-07-24 | 2023-09-11 | ContractNo_NTP SS | 46d | 0d |  | DE | D-B | DES | NS | PC |
| ContractNo_1910 |  | Schedule & Conduct OTS Review - Traffic Management Plan (Stage 1) | 2d | 2023-09-12 | 2023-09-13 | ContractNo_1900 | 46d | 0d |  | DE | D-B | DES | NS | PC |
| ContractNo_1810 |  | Submit Traffic Management Plan (Stage 1) | 4d | 2023-09-14 | 2023-09-19 | ContractNo_1910 | 46d | 0d |  | DE | D-B | DES | NS | PC |
| ContractNo_2030 |  | Review & Approve Traffic Management Plan (Stage 1) | 30d | 2023-09-20 | 2023-10-19 | ContractNo_1810 | 68d | 0d | Cal03A - 7d/8hr/No Holidays | DE | DOT | DES | NS | PC |
| ContractNo_1820 |  | Comment Resolution & Reissue Traffic Management Plan | 10d | 2023-10-20 | 2023-11-02 | ContractNo_1810, ContractNo_2030 | 46d | 18d |  | DE | D-B | DES | NS | PC |

| ID | WBS | Activity | Duration | Start | Finish | Predecessors | Total float | Free float | Calendar | CST-SubPhase | CST-Responsibility | CST-Type | CST-Step | CST-Phase |
| --- | --- | --- | --- | --- | --- | --- | --- | --- | --- | --- | --- | --- | --- | --- |
|  | 11 | **Existing Bridge Monitoring Plan** |  | 2023-07-24 | 2023-08-18 |  |  |  |  |  |  |  |  |  |
| ContractNo_2210 |  | Prepare & Submit Existing Bridge Monitoring Plan | 20d | 2023-07-24 | 2023-08-18 | ContractNo_NTP SS | 214d | 201d |  | DE | D-B | DES | NS | PC |
|  | 12 | **Dewatering Plan** |  | 2023-07-24 | 2023-11-01 |  |  |  |  |  |  |  |  |  |
| ContractNo_2380 |  | Prepare & Submit Dewatering Plan | 50d | 2023-07-24 | 2023-10-02 | ContractNo_NTP SS | 419d | 0d |  | DE | D-B | DES | NS | PC |
| ContractNo_2390 |  | Review & Approve Dewatering Plan | 30d | 2023-10-03 | 2023-11-01 | ContractNo_2380 | 615d |  | Cal03A - 7d/8hr/No Holidays | DE | DOT | DES | NS | PC |
|  | 6 | **Demolition Plan - NB** |  | 2023-07-24 | 2023-12-29 |  |  |  |  |  |  |  |  |  |
| ContractNo_2170 |  | Prepare & Submit Demolition Plan | 90d | 2023-07-24 | 2023-11-29 | ContractNo_NTP SS | 123d | 0d |  | DE | D-B | DES | NS | PC |
| ContractNo_2180 |  | Review & Approve Demolition Plan | 30d | 2023-11-30 | 2023-12-29 | ContractNo_2170 | 181d | 163d | Cal03A - 7d/8hr/No Holidays | DE | DOT | DES | NS | PC |
|  | 13 | **Drilled Shaft Installation/Testing Procedure** |  | 2023-07-24 | 2023-11-30 |  |  |  |  |  |  |  |  |  |
| ContractNo_2240 |  | Prepare & Submit Drilled Shaft Installation/Testing Procedure | 70d | 2023-07-24 | 2023-10-31 | ContractNo_NTP SS | 399d | 0d |  | DE | D-B | DES | NS | PC |
| ContractNo_2250 |  | Review & Approve Drilled Shaft Installation/Testing Procedure | 30d | 2023-11-01 | 2023-11-30 | ContractNo_2240 | 586d |  | Cal03A - 7d/8hr/No Holidays | DE | DOT | DES | NS | PC |
|  | 5 | **Abutment Pile Intsallation Plan** |  | 2023-07-24 | 2023-10-18 |  |  |  |  |  |  |  |  |  |
| ContractNo_2260 |  | Prepare & Submit Abutment Pile Installation Plan | 40d | 2023-07-24 | 2023-09-18 | ContractNo_NTP SS | 429d | 0d |  | DE | D-B | DES | NS | PC |
| ContractNo_2270 |  | Review & Approve Abutment Pile Installation Plan | 30d | 2023-09-19 | 2023-10-18 | ContractNo_2260 | 629d |  | Cal03A - 7d/8hr/No Holidays | DE | DOT | DES | NS | PC |
|  | 7 | **Erection Plan - Stage 1** |  | 2023-07-24 | 2023-11-16 |  |  |  |  |  |  |  |  |  |
| ContractNo_2190 |  | Prepare & Submit Erection Plan - Stage 1 | 60d | 2023-07-24 | 2023-10-17 | ContractNo_NTP SS | 175d | 0d |  | DE | D-B | DES | STL | PC |
| ContractNo_2200 |  | Review & Approve Erection Plan - Stage 1 | 30d | 2023-10-18 | 2023-11-16 | ContractNo_2190 | 257d | 0d | Cal03A - 7d/8hr/No Holidays | DE | DOT | DES | STL | PC |
|  | 3 | **Erection Plan - Stage 2** |  | 2023-11-17 | 2024-03-15 |  |  |  |  |  |  |  |  |  |
| ContractNo_2280 |  | Prepare & Submit Erection Plan - Stage 2 | 60d | 2023-11-17 | 2024-02-14 | ContractNo_2200, ContractNo_NTP SS | 327d | 0d |  | DE | D-B | DES | STL | PC |
| ContractNo_2290 |  | Review & Approve Erection Plan - Stage 2 | 30d | 2024-02-15 | 2024-03-15 | ContractNo_2280 | 480d |  | Cal03A - 7d/8hr/No Holidays | DE | DOT | DES | STL | PC |
|  | 4 | **Erection Plan - Stage 3** |  | 2023-07-24 | 2023-11-16 |  |  |  |  |  |  |  |  |  |
| ContractNo_2300 |  | Prepare & Submit Erection Plan - Stage 3 | 60d | 2023-07-24 | 2023-10-17 | ContractNo_NTP SS | 409d | 0d |  | DE | D-B | DES | STL | PC |
| ContractNo_2310 |  | Review & Approve Erection Plan - Stage 3 | 30d | 2023-10-18 | 2023-11-16 | ContractNo_2300 | 600d |  | Cal03A - 7d/8hr/No Holidays | DE | DOT | DES | STL | PC |
|  | 10 | **Deck Placement Plan** |  | 2023-07-24 | 2023-12-29 |  |  |  |  |  |  |  |  |  |
| ContractNo_2320 |  | Prepare & Submit Deck Placement Plan | 90d | 2023-07-24 | 2023-11-29 | ContractNo_NTP SS | 379d | 0d |  | DE | D-B | DES | NS | PC |
| ContractNo_2330 |  | Review & Approve Deck Placement Plan | 30d | 2023-11-30 | 2023-12-29 | ContractNo_2320 | 557d |  | Cal03A - 7d/8hr/No Holidays | DE | DOT | DES | NS | PC |

| ID | WBS | Activity | Duration | Start | Finish | Predecessors | Total float | Free float | Calendar | CST-SubPhase | CST-Responsibility | CST-Type | CST-Step | CST-Phase |
| --- | --- | --- | --- | --- | --- | --- | --- | --- | --- | --- | --- | --- | --- | --- |
|  | 8 | **Solid Pier Wall Construction Plan** |  | 2023-07-24 | 2023-11-16 |  |  |  |  |  |  |  |  |  |
| ContractNo_2340 |  | Prepare & Submit Solid Pier Wall Construction Plan | 60d | 2023-07-24 | 2023-10-17 | ContractNo_NTP SS | 409d | 0d |  | DE | D-B | DES | NS | PC |
| ContractNo_2350 |  | Review & Approve Solid Pier Wall Construction Plan | 30d | 2023-10-18 | 2023-11-16 | ContractNo_2340 | 600d |  | Cal03A - 7d/8hr/No Holidays | DE | DOT | DES | NS | PC |
|  | 9 | **Formwork Plan** |  | 2023-07-24 | 2023-11-16 |  |  |  |  |  |  |  |  |  |
| ContractNo_2360 |  | Prepare & Submit Formwork Plan | 60d | 2023-07-24 | 2023-10-17 | ContractNo_NTP SS | 409d | 0d |  | DE | D-B | DES | NS | PC |
| ContractNo_2370 |  | Review & Approve Formwork Plan | 30d | 2023-10-18 | 2023-11-16 | ContractNo_2360 | 600d |  | Cal03A - 7d/8hr/No Holidays | DE | DOT | DES | NS | PC |
|  | 1 | **Subcontractor Approvals** |  |  |  |  |  |  |  |  |  |  |  |  |
|  | 1 | **Licensed Site Professional** |  |  |  |  |  |  |  |  |  |  |  |  |
|  | 2 | **Structure Cleaning Subcontractor** |  |  |  |  |  |  |  |  |  |  |  |  |
|  | 3 | **Electrical Subcontractor** |  |  |  |  |  |  |  |  |  |  |  |  |
|  | 4 | **Bridge Demolition Subcontractor** |  |  |  |  |  |  |  |  |  |  |  |  |
|  | 8 | **Shop Drawings and Procurements** |  | 2023-07-24 | 2024-03-24 |  |  |  |  |  |  |  |  |  |
|  | 16 | **Superstructure Rebar Design** |  | 2023-07-24 | 2023-10-25 |  |  |  |  |  |  |  |  |  |
| ContractNo_3040 |  | Prepare & Submit Early Release Superstructure Rebar Design | 45d | 2023-07-24 | 2023-09-25 | ContractNo_NTP SS | 333d | 0d |  | DE | D-B | DES | NS | PC |
| ContractNo_3050 |  | Review & Approve Early Release Superstructure Rebar Design | 30d | 2023-09-26 | 2023-10-25 | ContractNo_3040 | 490d | 0d | Cal03A - 7d/8hr/No Holidays | DE | DOT | DES | NS | PC |
|  | 9 | **Abutment Rebar** |  | 2023-07-24 | 2023-10-17 |  |  |  |  |  |  |  |  |  |
| ContractNo_3010 |  | Prepare & Submit Substructure Rebar Shop Drawings | 20d | 2023-07-24 | 2023-08-18 | ContractNo_NTP SS | 430d | 0d |  | DE | D-B | DES | NS | PC |
| ContractNo_3020 |  | Review & Approve Substructure Rebar Shop Drawings | 30d | 2023-08-19 | 2023-09-17 | ContractNo_3010 | 630d | 0d | Cal03A - 7d/8hr/No Holidays | DE | DOT | DES | NS | PC |
| ContractNo_3030 |  | Procure Substructure Rebar | 30d | 2023-09-18 | 2023-10-17 | ContractNo_3020 | 630d |  | Cal03A - 7d/8hr/No Holidays | PR | D-B | PRO | NS | PC |
|  | 14 | **Drilled Shaft Rebar** |  | 2023-07-24 | 2023-10-17 |  |  |  |  |  |  |  |  |  |
| ContractNo_3510 |  | Prepare & Submit Drilled Shaft Rebar Shop Drawings | 20d | 2023-07-24 | 2023-08-18 | ContractNo_NTP SS | 430d | 0d |  | DE | D-B | DES | NS | PC |
| ContractNo_3520 |  | Review & Approve Drilled Shaft Rebar Shop Drawings | 30d | 2023-08-19 | 2023-09-17 | ContractNo_3510 | 630d | 0d | Cal03A - 7d/8hr/No Holidays | DE | DOT | DES | NS | PC |
| ContractNo_3530 |  | Procure Drilled Shaft Rebar | 30d | 2023-09-18 | 2023-10-17 | ContractNo_3520 | 630d |  | Cal03A - 7d/8hr/No Holidays | PR | D-B | PRO | NS | PC |
|  | 15 | **Pier Substructure Rebar** |  | 2023-07-24 | 2023-11-01 |  |  |  |  |  |  |  |  |  |
| ContractNo_3540 |  | Prepare & Submit Pier Substructure Rebar Shop Drawings | 20d | 2023-07-24 | 2023-08-18 | ContractNo_NTP SS | 419d | 0d |  | DE | D-B | DES | NS | PC |
| ContractNo_3550 |  | Review & Approve Pier Substructure Rebar Shop Drawings | 30d | 2023-08-19 | 2023-09-17 | ContractNo_3540 | 615d | 0d | Cal03A - 7d/8hr/No Holidays | DE | DOT | DES | NS | PC |
| ContractNo_3560 |  | Procure Pier Substructure Rebar | 45d | 2023-09-18 | 2023-11-01 | ContractNo_3550 | 615d |  | Cal03A - 7d/8hr/No Holidays | PR | D-B | PRO | NS | PC |

| ID | WBS | Activity | Duration | Start | Finish | Predecessors | Total float | Free float | Calendar | CST-SubPhase | CST-Responsibility | CST-Type | CST-Step | CST-Phase |
| --- | --- | --- | --- | --- | --- | --- | --- | --- | --- | --- | --- | --- | --- | --- |
|  | 3 | **Stay in Place Formwork** |  | 2023-07-24 | 2023-11-16 |  |  |  |  |  |  |  |  |  |
| ContractNo_3330 |  | Prepare & Submit Stay in Place Formwork | 20d | 2023-07-24 | 2023-08-18 | ContractNo_NTP SS | 409d | 0d |  | DE | D-B | DES | NS | PC |
| ContractNo_3340 |  | Review & Approve Stay in Place Formwork | 30d | 2023-08-19 | 2023-09-17 | ContractNo_3330 | 600d | 0d | Cal03A - 7d/8hr/No Holidays | DE | DOT | DES | NS | PC |
| ContractNo_3350 |  | Procure Stay in Place Formwork | 60d | 2023-09-18 | 2023-11-16 | ContractNo_3340 | 600d |  | Cal03A - 7d/8hr/No Holidays | PR | D-B | PRO | NS | PC |
|  | 7 | **Solid Pier Wall (Pier Bases) Design & Shop Drawings** |  | 2023-07-24 | 2024-03-24 |  |  |  |  |  |  |  |  |  |
| ContractNo_3130 |  | Prepare & Submit - Solid Pier Wall (Pier Bases) Design | 60d | 2023-07-24 | 2023-10-17 | ContractNo_NTP SS | 322d | 0d |  | DE | D-B | DES | NS | PC |
| ContractNo_3140 |  | Review & Approve - Solid Pier Wall (Pier Bases) Design | 30d | 2023-10-18 | 2023-11-16 | ContractNo_3130 | 472d | 0d | Cal03A - 7d/8hr/No Holidays | DE | DOT | DES | NS | PC |
| ContractNo_3070 |  | Prepare & Submit - Solid Pier Wall (Pier Bases) Shop Drawings | 20d | 2023-11-17 | 2023-12-15 | ContractNo_3140 | 319d | 0d |  | DE | D-B | DES | NS | PC |
| ContractNo_3080 |  | Review & Approve Solid Pier Wall Shop Drawings | 30d | 2023-12-16 | 2024-01-14 | ContractNo_3070 | 471d | 0d | Cal03A - 7d/8hr/No Holidays | DE | DOT | DES | NS | PC |
| ContractNo_3090 |  | Procure Solid Pier Wall Material | 70d | 2024-01-15 | 2024-03-24 | ContractNo_3080 | 471d |  | Cal03A - 7d/8hr/No Holidays | PR | D-B | PRO | NS | PC |
|  | 5 | **Drainage Structures** |  | 2023-07-24 | 2023-10-12 |  |  |  |  |  |  |  |  |  |
| ContractNo_3100 |  | Prepare & Submit Drainage Structures | 20d | 2023-07-24 | 2023-08-18 | ContractNo_NTP SS | 433d | 0d |  | DE | D-B | DES | NS | PC |
| ContractNo_3110 |  | Review & Approve Drainage Structures | 30d | 2023-08-19 | 2023-09-17 | ContractNo_3100 | 635d | 0d | Cal03A - 7d/8hr/No Holidays | DE | DOT | DES | NS | PC |
| ContractNo_3120 |  | Procure Drainage Structures | 25d | 2023-09-18 | 2023-10-12 | ContractNo_3110 | 635d |  | Cal03A - 7d/8hr/No Holidays | PR | D-B | PRO | NS | PC |
|  | 1 | **TL-5 Pier Protection Barrier** |  | 2023-07-24 | 2023-10-22 |  |  |  |  |  |  |  |  |  |
| ContractNo_3160 |  | Prepare & Submit TL-5 Pier Protection Barrier | 20d | 2023-07-24 | 2023-08-18 | ContractNo_NTP SS | 425d | 0d |  | DE | D-B | DES | NS | PC |
| ContractNo_3170 |  | Review & Approve TL-5 Pier Protection Barrier | 30d | 2023-08-19 | 2023-09-17 | ContractNo_3160 | 625d | 0d | Cal03A - 7d/8hr/No Holidays | DE | DOT | DES | NS | PC |
| ContractNo_3180 |  | Procure TL-5 Pier Protection Barrier | 35d | 2023-09-18 | 2023-10-22 | ContractNo_3170 | 625d |  | Cal03A - 7d/8hr/No Holidays | PR | D-B | PRO | NS | PC |
|  | 12 | **Bridge Bearings** |  | 2023-07-24 | 2023-11-30 |  |  |  |  |  |  |  |  |  |
| ContractNo_3220 |  | Prepare & Submit Bridge Bearings Shop Drawings | 30d | 2023-07-24 | 2023-09-01 | ContractNo_NTP SS | 399d | 0d |  | DE | D-B | DES | NS | PC |
| ContractNo_3230 |  | Review & Approve Bridge Bearings Shop Drawings | 30d | 2023-09-02 | 2023-10-01 | ContractNo_3220 | 586d | 0d | Cal03A - 7d/8hr/No Holidays | DE | DOT | DES | NS | PC |
| ContractNo_3190 |  | Procure Bridge Bearings | 60d | 2023-10-02 | 2023-11-30 | ContractNo_3230 | 586d |  | Cal03A - 7d/8hr/No Holidays | PR | D-B | PRO | NS | PC |
|  | 4 | **Superstructure Rebar** |  | 2023-10-26 | 2024-03-06 |  |  |  |  |  |  |  |  |  |
| ContractNo_3360 |  | Prepare & Submit Superstructure Rebar Shop Drawings | 30d | 2023-10-26 | 2023-12-07 | ContractNo_3050, ContractNo_NTP SS | 333d | 0d |  | DE | D-B | DES | NS | PC |
| ContractNo_3370 |  | Review & Approve Superstructure Rebar Shop Drawings | 30d | 2023-12-08 | 2024-01-06 | ContractNo_3360 | 489d | 0d | Cal03A - 7d/8hr/No Holidays | DE | DOT | DES | NS | PC |
| ContractNo_3060 |  | Procure Superstructure Rebar | 60d | 2024-01-07 | 2024-03-06 | ContractNo_3370 | 489d |  | Cal03A - 7d/8hr/No Holidays | PR | D-B | PRO | NS | PC |

| ID | WBS | Activity | Duration | Start | Finish | Predecessors | Total float | Free float | Calendar | CST-SubPhase | CST-Responsibility | CST-Type | CST-Step | CST-Phase |
| --- | --- | --- | --- | --- | --- | --- | --- | --- | --- | --- | --- | --- | --- | --- |
|  | 6 | **Bridge Scuppers** |  | 2023-07-24 | 2023-11-30 |  |  |  |  |  |  |  |  |  |
| ContractNo_3380 |  | Prepare & Submit Bridge Scupper Shop Drawings | 30d | 2023-07-24 | 2023-09-01 | ContractNo_NTP SS | 399d | 0d |  | DE | D-B | DES | NS | PC |
| ContractNo_3390 |  | Review & Approve Bridge Scupper Shop Drawings | 30d | 2023-09-02 | 2023-10-01 | ContractNo_3380 | 586d | 0d | Cal03A - 7d/8hr/No Holidays | DE | DOT | DES | NS | PC |
| ContractNo_3200 |  | Procure/Fabricate Bridge Scuppers | 60d | 2023-10-02 | 2023-11-30 | ContractNo_3390 | 586d |  | Cal03A - 7d/8hr/No Holidays | PR | D-B | PRO | NS | PC |
|  | 8 | **Bridge Joint** |  | 2023-07-24 | 2023-11-30 |  |  |  |  |  |  |  |  |  |
| ContractNo_3400 |  | Prepare & Submit Bridge Shop Drawings | 30d | 2023-07-24 | 2023-09-01 | ContractNo_NTP SS | 399d | 0d |  | DE | D-B | DES | NS | PC |
| ContractNo_3410 |  | Review & Approve Bridge Joint Design | 30d | 2023-09-02 | 2023-10-01 | ContractNo_3400 | 586d | 0d | Cal03A - 7d/8hr/No Holidays | DE | DOT | DES | NS | PC |
| ContractNo_3210 |  | Procure/Fabricate Bridge Joint | 60d | 2023-10-02 | 2023-11-30 | ContractNo_3410 | 586d |  | Cal03A - 7d/8hr/No Holidays | PR | D-B | PRO | NS | PC |
|  | 9 | **Early Action Permit Plan Changes** |  | 2023-07-24 | 2023-10-30 |  |  |  |  |  |  |  |  |  |
|  | 1 | **National Marine Fishery Service (NMFS)** |  | 2023-07-24 | 2023-10-29 |  |  |  |  |  |  |  |  |  |
| ContractNo_1300 |  | Prepare & Submit Revised Section 7 Letter | 25d | 2023-07-24 | 2023-08-25 | ContractNo_NTP SS | 177d | 0d |  | PE | D-B | DES | NS | PC |
| ContractNo_1310 |  | Review & Approve Revised Section 7 Letter | 30d | 2023-08-26 | 2023-09-24 | ContractNo_1300 | 260d | 0d | Cal03A - 7d/8hr/No Holidays | PE | DOT | DES | NS | PC |
| ContractNo_1330 |  | Comment Resolution & Reissue Revised Section 7 Letter | 5d | 2023-09-25 | 2023-09-29 | ContractNo_1310 | 178d | 0d |  | PE | D-B | DES | NS | PC |
| ContractNo_1320 |  | NMFS - Review & Approve Revised Section 7 Letter | 30d | 2023-09-30 | 2023-10-29 | ContractNo_1310, ContractNo_1330 | 617d | 0d | Cal03A - 7d/8hr/No Holidays | PE | NMFS | DES | NS | PC |
|  | 11 | **Water Quality Certification Permit Plan Changes** |  | 2023-07-24 | 2023-10-30 |  |  |  |  |  |  |  |  |  |
| ContractNo_1220 |  | Prepare & Submit WQC Permit Plan Changes | 20d | 2023-07-24 | 2023-08-18 | ContractNo_NTP SS | 425d | 0d |  | PE | D-B | DES | NS | PC |
| ContractNo_1240 |  | Review & Approve WQC Permit Plan Changes | 30d | 2023-08-19 | 2023-09-17 | ContractNo_1220 | 623d | 0d | Cal03A - 7d/8hr/No Holidays | PE | DOT | DES | NS | PC |
| ContractNo_1280 |  | Comment Resolution & Reissue WQC Permit Plan Changes | 5d | 2023-09-18 | 2023-09-22 | ContractNo_1240 | 425d | 0d |  | PE | D-B | DES | NS | PC |
| ContractNo_1260 |  | MassDEP - Review & Approve WQC Permit Plan Changes | 30d | 2023-09-22 | 2023-10-22 | ContractNo_1240, ContractNo_1280 | 624.67d | 7.67d | Cal04-7d/24Hr/No Hol (Milestones) | PE | DEP | DES | NS | PC |
| ContractNo_1340 |  | MassDEP - Issue WQC Permit Plan Changes | 1d | 2023-10-30 | 2023-10-30 | ContractNo_1260, ContractNo_1320 | 420d |  |  | PE | DEP | DES | NS | PC |
|  | 12 | **Army Corp of Engineers Permit Plan Changes** |  | 2023-07-24 | 2023-10-30 |  |  |  |  |  |  |  |  |  |
| ContractNo_1230 |  | Prepare & Submit ACOE Permit Plan Changes | 17d | 2023-07-24 | 2023-08-15 | ContractNo_NTP SS | 428d | 0d |  | PE | D-B | DES | NS | PC |
| ContractNo_1250 |  | Review & Approve ACOE Permit Plan Changes | 30d | 2023-08-16 | 2023-09-14 | ContractNo_1230 | 626d | 0d | Cal03A - 7d/8hr/No Holidays | PE | DOT | DES | NS | PC |
| ContractNo_1290 |  | Comment Resolution & Reissue ACOE Permit Plan Changes | 5d | 2023-09-15 | 2023-09-21 | ContractNo_1250 | 426d | 0d |  | PE | D-B | DES | NS | PC |
| ContractNo_1270 |  | ACOE - Review & Approve ACOE Permit Plan Changes | 30d | 2023-09-21 | 2023-10-21 | ContractNo_1250, ContractNo_1290 | 625.67d | 8.67d | Cal04-7d/24Hr/No Hol (Milestones) | PE | ACO | DES | NS | PC |
| ContractNo_1350 |  | ACOE - Issue ACOE Permit Plan Changes | 1d | 2023-10-30 | 2023-10-30 | ContractNo_1270, ContractNo_1320 | 420d |  |  | PE | ACO | DES | NS | PC |

| ID | WBS | Activity | Duration | Start | Finish | Predecessors | Total float | Free float | Calendar | CST-SubPhase | CST-Responsibility | CST-Type | CST-Step | CST-Phase | CST-Location |
| --- | --- | --- | --- | --- | --- | --- | --- | --- | --- | --- | --- | --- | --- | --- | --- |
|  | Uti | **Utility** |  | 2023-08-02 | 2024-04-10 |  |  |  |  |  |  |  |  |  |  |
|  | URP | **Utility Relocation & Coordination Plan** |  | 2023-08-02 | 2023-08-22 |  |  |  |  |  |  |  |  |  |  |
| ContractNo_P250 |  | Prepare & Submit - Early Utiltiy Relocation Request\Coordination Plan | 14d | 2023-08-02 | 2023-08-15 | ContractNo_NTP SS, ContractNo_PCM2 SS | 125d | 0d | Cal03A - 7d/8hr/No Holidays | PR | D-B | PRO | URP | PC |  |
| ContractNo_P260 |  | Review & Approve - Early Utiltiy Relocation Request\Coordination Plan | 7d | 2023-08-16 | 2023-08-22 | ContractNo_P250 | 125d | 0d | Cal03A - 7d/8hr/No Holidays | PR | DOT | PRO | URP | PC |  |
|  | Not | **Utility Notifications & Meetings** |  | 2023-08-23 | 2023-09-21 |  |  |  |  |  |  |  |  |  |  |
| ContractNo_U100 |  | Coordinate/Mobilization Period - Relocation w/ Utility Company - [insert Utility 1 Name] | 30d | 2023-08-23 | 2023-09-21 | ContractNo_P260 | 125d | 54.4d | Cal03A - 7d/8hr/No Holidays | GN | D-B | UTIL | NS | UR |  |
| ContractNo_U350 |  | Coordinate/Mobilization Period - Relocation w/ Utility Company - [insert Utility 2 Name] | 30d | 2023-08-23 | 2023-09-21 | ContractNo_P260 | 161d | 90.4d | Cal03A - 7d/8hr/No Holidays | GN | D-B | UTIL | NS | UR |  |
| ContractNo_U360 |  | Coordinate/Mobilization Period - Relocation w/ Utility Company - [insert Utility 3 Name] | 30d | 2023-08-23 | 2023-09-21 | ContractNo_P260 | 196d | 130.4d | Cal03A - 7d/8hr/No Holidays | GN | D-B | UTIL | NS | UR |  |
| ContractNo_U370 |  | Coordinate/Mobilization Period - Relocation w/ Utility Company - [insert Utility 4 Name] | 30d | 2023-08-23 | 2023-09-21 | ContractNo_P260 | 234d | 166.4d | Cal03A - 7d/8hr/No Holidays | GN | D-B | UTIL | NS | UR |  |
|  | Rel | **Utility Relocation** |  | 2023-11-15 | 2024-04-10 |  |  |  |  |  |  |  |  |  |  |
|  | 1 | **Utility 1 PUC Tasks** |  | 2023-11-15 | 2023-12-21 |  |  |  |  |  |  |  |  |  |  |
| ContractNo_U340 |  | Utility 1 Task 1: Copy Activity Name from PUC Form | 20d | 2023-11-15 | 2023-12-14 | ContractNo_U100, ContractNo_C900 | 46.6d | 0d |  | GN | D-B | UTIL | NS | UR |  |
| ContractNo_U120 |  | Utility 1 Task 2: Copy Activity Name from PUC Form | 5d | 2023-12-14 | 2023-12-21 | ContractNo_U340 | 46.6d | 0d |  | GN | D-B | UTIL | NS | UR |  |
|  | 2 | **Utility 2 PUC Tasks** |  | 2023-12-21 | 2024-01-30 |  |  |  |  |  |  |  |  |  |  |
| ContractNo_U380 |  | Utility 2 Task 1: Copy Activity Name from PUC Form | 20d | 2023-12-21 | 2024-01-23 | ContractNo_U120, ContractNo_U350 | 46.6d | 0d |  | GN | D-B | UTIL | NS | UR |  |
| ContractNo_U390 |  | Utility 2 Task 2: Copy Activity Name from PUC Form | 5d | 2024-01-23 | 2024-01-30 | ContractNo_U380 | 46.6d | 0d |  | GN | D-B | UTIL | NS | UR |  |
|  | 3 | **Utility 3 PUC Tasks** |  | 2024-01-30 | 2024-03-06 |  |  |  |  |  |  |  |  |  |  |
| ContractNo_U400 |  | Utility 3 Task 1: Copy Activity Name from PUC Form | 20d | 2024-01-30 | 2024-02-28 | ContractNo_U390, ContractNo_U360 | 46.6d | 0d |  | GN | D-B | UTIL | NS | UR |  |
| ContractNo_U410 |  | Utility 3 Task 2: Copy Activity Name from PUC Form | 5d | 2024-02-28 | 2024-03-06 | ContractNo_U400 | 46.6d | 0d |  | GN | D-B | UTIL | NS | UR |  |
|  | 4 | **Utility 4 PUC Tasks** |  | 2024-03-06 | 2024-04-10 |  |  |  |  |  |  |  |  |  |  |
| ContractNo_U420 |  | Utility 4 Task 1: Copy Activity Name from PUC Form | 20d | 2024-03-06 | 2024-04-03 | ContractNo_U410, ContractNo_U370 | 46.6d | 0d |  | GN | D-B | UTIL | NS | UR |  |
| ContractNo_U430 |  | Utility 4 Task 2: Copy Activity Name from PUC Form | 5d | 2024-04-03 | 2024-04-10 | ContractNo_U420 | 46.6d | 0d |  | GN | D-B | UTIL | NS | UR |  |
|  | ServConn | **Utility Service Connections** |  | 2023-08-02 | 2023-09-13 |  |  |  |  |  |  |  |  |  |  |
| ContractNo_U440 |  | Design-Builder Request WO# for Service Connection @ Location XXX (If Required) | 5d | 2023-08-02 | 2023-08-08 | ContractNo_PCM2 SS | 93d | 0d |  | P03 | D-B | UTIL | SD | UR | Quadrant 3 |
| ContractNo_U450 |  | Utility Assigns WO# for Service Connection @ Location XXX (If Required) | 5d | 2023-08-09 | 2023-08-15 | ContractNo_U440 | 93d | 0d |  | P03 | UKE | UTIL | SD | UR | Quadrant 3 |
| ContractNo_U460 |  | Utility Completes Design and Requests Payment for WO# @ Location XXX (If Required) | 20d | 2023-08-15 | 2023-09-04 | ContractNo_U450 | 135.67d | 0.67d | Cal04-7d/24Hr/No Hol (Milestones) | P03 | UKE | UTIL | SD | UR | Quadrant 3 |
| ContractNo_U470 |  | Design-Builder installs UG conduit @ Location XXX (If Required) | 5d | 2023-09-05 | 2023-09-11 | ContractNo_U460 | 92d | 0d |  | P03 | D-B | UTIL | SD | UR | Quadrant 3 |
| ContractNo_U480 |  | Utility Performs Service Connection @ Location XXX (If Required) | 2d | 2023-09-12 | 2023-09-13 | ContractNo_U470 | 401d |  |  | P03 | UKE | UTIL | SD | UR | Quadrant 3 |

| ID | WBS | Activity | Type | Duration | Start | Finish | Predecessors | Total float | Free float | Calendar | Resources | CST-SubPhase | CST-Responsibility | CST-Type | CST-Step | CST-Phase |
| --- | --- | --- | --- | --- | --- | --- | --- | --- | --- | --- | --- | --- | --- | --- | --- | --- |
|  | Con | **Construction** |  |  | 2023-01-03 | 2025-05-01 |  |  |  |  |  |  |  |  |  |  |
|  | Gene | **General** |  |  | 2023-07-24 | 2023-08-02 |  |  |  |  |  |  |  |  |  |  |
| ContractNo_PCM1 |  | Schedule Pre-Construction Meeting/Schedule Planning Session |  | 7d | 2023-07-24 | 2023-08-01 | ContractNo_NTP SS | 86d | 0d |  |  | GN | DOT | NA | NS | PC |
| ContractNo_PCM2 |  | Conduct Pre-Construction Meeting/Schedule Planning Session | milestone | 0d | 2023-08-02 | 2023-08-02 | ContractNo_PCM1 | 86d | 0d |  |  | GN | DOT | NA | NS | PC |
|  | Mobi | **Start-up** |  |  | 2023-01-03 | 2023-11-15 |  |  |  |  |  |  |  |  |  |  |
| ContractNo_C910 |  | MassDOT Baseline Survey / Layout of Utility Pole Locations |  | 20d | 2023-01-03 | 2023-01-31 |  | 240d | 193.4d |  | Bid Item Value [80 h] | GN | D-B | NA | NS | CN |
| ContractNo_C070 |  | Design-Builder Mobilize |  | 20d | 2023-08-02 | 2023-08-29 | ContractNo_NTP SS, ContractNo_PCM2 SS | 90d | 0d |  | Bid Item Value [160 h] | GN | D-B | NA | NS | CN |
| ContractNo_C100 |  | Establish Engineer's Field Office |  | 20d | 2023-08-02 | 2023-08-29 | ContractNo_C070 SS, ContractNo_PCM2 SS | 90d | 43.4d |  | Bid Item Value [80 h] | GN | D-B | NA | NS | CN |
| ContractNo_C370 |  | Install Traffic Devices, RTTM System, Barriers, Signage |  | 5d | 2023-11-01 | 2023-11-08 | ContractNo_C100, ContractNo_2030, ContractNo_1490 | 46.6d | 0d |  |  | GN | D-B | SITE | NS | CN |
| ContractNo_C080 |  | Install SWPPP Systems |  | 5d | 2023-11-08 | 2023-11-15 | ContractNo_C070, ContractNo_C370, ContractNo_1530 | 146.6d | 100d |  |  | GN | D-B | SITE | NS | CN |
| ContractNo_C900 |  | Design-Builder Performs Utility Enabling Work (If Required) |  | 5d | 2023-11-08 | 2023-11-15 | ContractNo_C910, ContractNo_C370, ContractNo_U470 SS | 46.6d | 0d |  |  | GN | D-B | SITE | NS | CN |
|  | Ph1 | **Stage 1** |  |  | 2024-04-10 | 2024-09-11 |  |  |  |  |  |  |  |  |  |  |
|  | StpA | **Step A** |  |  | 2024-04-10 | 2024-07-15 |  |  |  |  |  |  |  |  |  |  |
| ContractNo_C465 |  | Install Temporary Shielding - [Location] |  | 7d | 2024-04-10 | 2024-04-22 | ContractNo_C080, ContractNo_U430 | 46.6d | 33.6d |  |  | P01 | D-B | DEMO | SA | CN |
| ContractNo_C480 |  | Environmental Protection of Box Turtles |  | 5d | 2024-06-03 | 2024-06-07 | ContractNo_1330 | 11d | 0d | Cal15-Wtr Acc 1-5d/12hol |  | P01 | D-B | EART | SA | CN |
| ContractNo_C475 |  | Demo Existing Superstructure - [Location] |  | 4d | 2024-06-10 | 2024-06-13 | ContractNo_C080, ContractNo_C465, ContractNo_2180, ContractNo_2210, ContractNo_C480 | 13d | 2d |  | Bid Item Value [32 h]; Laborer [32 h]; Operator [32 h]; Steel Worker [32 h]; Electrician [32 h]; Foreman [32 h]; Crane Type X [32 h]; Bulldozer Type X [32 h]; Excavator Type X [32 h]; Paver Type X [32 h]; Grader TypeX [32 h]; Compactor Type X [32 h] | P01 | D-B | DEMO | SA | CN |
| ContractNo_C485 |  | Install Water Control Measures - [Location] |  | 6d | 2024-06-10 | 2024-06-17 | ContractNo_C480, ContractNo_1530, ContractNo_2530 | 11d | 0d | Cal15-Wtr Acc 1-5d/12hol |  | P01 | D-B | WATE | SA | CN |
| ContractNo_C490 |  | Excavate Abutments & Surrounding Area - [Location] |  | 8d | 2024-06-18 | 2024-06-28 | ContractNo_C475, ContractNo_C485 | 11d | 0d |  | Laborer [210 h] | P01 | D-B | EART | SA | CN |
| ContractNo_C505 |  | Demo Existing Substructure - [Location] |  | 6d | 2024-07-01 | 2024-07-09 | ContractNo_C475, ContractNo_C485, ContractNo_C490, ContractNo_AR01 | 11d | 0d |  |  | P01 | D-B | DEMO | SA | CN |
| ContractNo_C515 |  | Set & Grout Precast Abutments - [Location] (NOTE: Ensure Grout Cure Period is accounted for) |  | 4d | 2024-07-10 | 2024-07-15 | ContractNo_C505 | 11d | 0d |  |  | P01 | D-B | CONC | SA | CN |
|  | StpB | **Step B** |  |  | 2024-07-16 | 2024-09-11 |  |  |  |  |  |  |  |  |  |  |
| ContractNo_C525 |  | Install Steel Beams - [Location] |  | 6d | 2024-07-16 | 2024-07-23 | ContractNo_C515, ContractNo_2200, ContractNo_1730 | 11d | 0d |  | Steel Worker [210 h] | P01 | D-B | STEE | SB | CN |
| ContractNo_C535 |  | Install Precast Decks - [Location] |  | 3d | 2024-07-24 | 2024-07-26 | ContractNo_C525 | 11d | 0d |  |  | P01 | D-B | CONC | SB | CN |
| ContractNo_C920 |  | Postension Precast Decks - [Location] |  | 1d | 2024-07-29 | 2024-07-29 | ContractNo_C535 | 11d | 0d |  |  | P01 | D-B | CONC | SB | CN |
| ContractNo_C545 |  | Grout Precast Decks - [Location] (NOTE: Ensure Grout Cure Period is accounted for) |  | 3d | 2024-07-30 | 2024-08-01 | ContractNo_C535, ContractNo_C920 | 11d | 0d |  |  | P01 | D-B | CONC | SB | CN |
| ContractNo_C555 |  | F/R/Pour Sidewalk Placement 1 - [Location] |  | 4d | 2024-08-02 | 2024-08-07 | ContractNo_C545 | 11d | 0d |  |  | P01 | D-B | CONC | SB | CN |
| ContractNo_C930 |  | 72 Hour Placement Cure Period for Sidewalks - [Location] |  | 3d | 2024-08-07 | 2024-08-10 | ContractNo_C555 | 15.67d | 1.67d | Cal04-7d/24Hr/No Hol (Milestones) |  | P01 | D-B | CONC | SB | CN |
| ContractNo_C940 |  | Sidewalk Placement 2 - [Location] |  | 2d | 2024-08-12 | 2024-08-13 | ContractNo_C930 | 10d | 0d |  |  | P01 | D-B | CONC | SB | CN |
| ContractNo_C950 |  | Full Cure Period for Sidewalks - [Location] |  | 14d | 2024-08-13 | 2024-08-27 | ContractNo_C940 | 14.67d | 0.67d | Cal04-7d/24Hr/No Hol (Milestones) |  | P01 | D-B | CONC | SB | CN |
| ContractNo_C575 |  | Install waterproofing - [Location] |  | 3d | 2024-08-28 | 2024-08-30 | ContractNo_C555, ContractNo_C950 | 9d | 0d | Cal12-Paving 5d/12hol |  | P01 | D-B | CONC | SB | CN |
| ContractNo_C580 |  | Place Protective Course Pavement - [Location] |  | 1d | 2024-09-03 | 2024-09-03 | ContractNo_C575, ContractNo_C950 | 9d | 0d | Cal12-Paving 5d/12hol |  | P01 | D-B | SITE | SB | CN |
| ContractNo_C565 |  | Install Railings - [Location] |  | 4d | 2024-09-04 | 2024-09-09 | ContractNo_C555, ContractNo_C950, ContractNo_C580 | 9d | 0d |  |  | P01 | D-B | STEE | SB | CN |
| ContractNo_C590 |  | Install Pavement Markers, Sign and Stripe - [Location] |  | 2d | 2024-09-04 | 2024-09-05 | ContractNo_C580 | 11d | 2d | Cal12-Paving 5d/12hol |  | P01 | D-B | SITE | SB | CN |
| ContractNo_C585 |  | Complete Phase 1 - [Location] | milestone | 0d | 2024-09-09 | 2024-09-09 | ContractNo_C590, ContractNo_C565 | 9d | 0d |  |  | P01 | D-B | NA | SB | CN |
| ContractNo_C595 |  | Set Jersey Barriers & Signage - [Location] |  | 2d | 2024-09-10 | 2024-09-11 | ContractNo_C590, ContractNo_C585 | 88d | 0d |  |  | P01 | D-B | SITE | SB | CN |

| ID | WBS | Activity | Type | Duration | Start | Finish | Predecessors | Total float | Free float | Calendar | Resources | CST-SubPhase | CST-Responsibility | CST-Type | CST-Step | CST-Phase |
| --- | --- | --- | --- | --- | --- | --- | --- | --- | --- | --- | --- | --- | --- | --- | --- | --- |
|  | StpC | **Step C** |  |  |  |  |  |  |  |  |  |  |  |  |  |  |
|  | StpD | **Step D** |  |  |  |  |  |  |  |  |  |  |  |  |  |  |
|  | Ph2 | **Stage 2** |  |  | 2024-09-10 | 2025-05-01 |  |  |  |  |  |  |  |  |  |  |
|  | StpA | **Step A** |  |  | 2024-09-10 | 2024-10-04 |  |  |  |  |  |  |  |  |  |  |
| ContractNo_C755 |  | Install Water Control Measures - [Location] |  | 6d | 2024-09-10 | 2024-09-17 | ContractNo_C585 | 9d | 0d | Cal15-Wtr Acc 1-5d/12hol |  | P02 | D-B | WATE | SA | CN |
| ContractNo_C750 |  | Traffic Switch from Phase I - [Location] |  | 2d | 2024-09-12 | 2024-09-13 | ContractNo_C595, ContractNo_C585 | 88d | 0d |  | Electrician [48 h] | P02 | D-B | SITE | SA | CN |
| ContractNo_C765 |  | Install Temporary Shielding - [Location] |  | 5d | 2024-09-16 | 2024-09-20 | ContractNo_C750 | 88d | 0d |  |  | P02 | D-B | DEMO | SA | CN |
| ContractNo_C790 |  | Excavate Abutments & Surrounding Area - [Location] |  | 8d | 2024-09-18 | 2024-09-27 | ContractNo_C755 | 101d | 0d |  | Laborer [210 h]; Foreman [64 h]; Bulldozer Type X [64 h]; Bid Item Value [64 h] | P02 | D-B | EART | SA | CN |
| ContractNo_C805 |  | Demo Existing Substructure - [Location] |  | 6d | 2024-09-23 | 2024-09-30 | ContractNo_C755, ContractNo_C765 | 88d | 0d |  |  | P02 | D-B | DEMO | SA | CN |
| ContractNo_C815 |  | Set & Grout Precast Abutments - [Location] (NOTE: Ensure Grout Cure Period is accounted for) |  | 4d | 2024-10-01 | 2024-10-04 | ContractNo_C805 | 88d | 0d |  |  | P02 | D-B | CONC | SA | CN |
|  | StpB | **Step B** |  |  | 2024-10-07 | 2025-04-23 |  |  |  |  |  |  |  |  |  |  |
| ContractNo_C825 |  | Install Steel Beams - [Location] |  | 6d | 2024-10-07 | 2024-10-15 | ContractNo_C815 | 88d | 0d |  | Steel Worker [210 h] | P02 | D-B | STEE | SB | CN |
| ContractNo_C835 |  | Install Precast Decks - [Location] |  | 4d | 2024-10-16 | 2024-10-21 | ContractNo_C825 | 88d | 0d |  |  | P02 | D-B | CONC | SB | CN |
| ContractNo_C960 |  | Postension Precast Decks - [Location] |  | 1d | 2024-10-22 | 2024-10-22 | ContractNo_C835 | 88d | 0d |  |  | P02 | D-B | CONC | SB | CN |
| ContractNo_C845 |  | Grout Precast Decks - [Location] |  | 3d | 2024-10-23 | 2024-10-25 | ContractNo_C835, ContractNo_C960 | 88d | 0d |  |  | P02 | D-B | CONC | SB | CN |
| ContractNo_C855 |  | F/R/Pour Sidewalk Placement 1 - [Location] |  | 2d | 2024-10-28 | 2024-10-29 | ContractNo_C845 | 88d | 0d |  |  | P02 | D-B | CONC | SB | CN |
| ContractNo_C970 |  | 72 Hour Placement Cure Period for Sidewalks - [Location] |  | 3d | 2024-10-29 | 2024-11-01 | ContractNo_C855 | 132.67d | 2.67d | Cal04-7d/24Hr/No Hol (Milestones) |  | P01 | D-B | CONC | SB | CN |
| ContractNo_C980 |  | Sidewalk Placement 2 - [Location] |  | 2d | 2024-11-04 | 2024-11-05 | ContractNo_C970 | 88d | 0d |  |  | P01 | D-B | CONC | SB | CN |
| ContractNo_C990 |  | Full Cure Period for Sidewalks - [Location] |  | 14d | 2024-11-05 | 2024-11-19 | ContractNo_C980 | 132.67d |  | Cal04-7d/24Hr/No Hol (Milestones) |  | P01 | D-B | CONC | SB | CN |
| ContractNo_C875 |  | Install waterproofing - [Location] |  | 3d | 2025-04-01 | 2025-04-03 | ContractNo_C855, ContractNo_C990 | 0d |  | Cal12-Paving 5d/12hol |  | P02 | D-B | CONC | SB | CN |
| ContractNo_C1000 |  | Place Protective Course Pavement - [Location] |  | 3d | 2025-04-04 | 2025-04-08 | ContractNo_C875 | 0d |  | Cal12-Paving 5d/12hol |  | P02 | D-B | CONC | SB | CN |
| ContractNo_C865 |  | Install Railings - [Location] |  | 4d | 2025-04-09 | 2025-04-14 | ContractNo_C855, ContractNo_C1000 | 0d |  |  |  | P02 | D-B | STEE | SB | CN |
| ContractNo_C880 |  | Place Base & Top Pavement - [Location] |  | 4d | 2025-04-15 | 2025-04-18 | ContractNo_C875, ContractNo_C320, ContractNo_C865 | 0d |  | Cal12-Paving 5d/12hol |  | P02 | D-B | SITE | SB | CN |
| ContractNo_C890 |  | Install Pavement Markers, Sign and Stripe - [Location] |  | 2d | 2025-04-22 | 2025-04-23 | ContractNo_C880 | 0d |  | Cal12-Paving 5d/12hol |  | P02 | D-B | SITE | SB | CN |
| ContractNo_C885 |  | Complete Phase 2 - [Location] | milestone | 0d | 2025-04-23 | 2025-04-23 | ContractNo_C890, ContractNo_C865 | 0d |  |  |  | P02 | D-B | NA | SB | CN |

| ID | WBS | Activity | Duration | Start | Finish | Predecessors | Planned start | Planned finish | Total float | Free float | Calendar | CST-SubPhase | CST-Responsibility | CST-Type | CST-Step | CST-Phase |
| --- | --- | --- | --- | --- | --- | --- | --- | --- | --- | --- | --- | --- | --- | --- | --- | --- |
|  | StpC | **Step C** |  | 2024-09-30 | 2025-05-01 |  |  |  |  |  |  |  |  |  |  |  |
| ContractNo_C190 |  | Approach Work - Raise Grades - [Location] | 16d | 2024-09-30 | 2024-10-22 | ContractNo_C790 |  |  | 101d | 0d |  | P02 | D-B | EART | SC | CN |
| ContractNo_C200 |  | Repair Underground Drainage Structure - [Location] | 5d | 2024-10-23 | 2024-10-29 | ContractNo_C190, ContractNo_U430 |  |  | 101d | 0d |  | P02 | D-B | SITE | SC | CN |
| ContractNo_C320 |  | Backfill & Grade - [Location] | 12d | 2024-10-30 | 2024-11-15 | ContractNo_C200 |  |  | 101d |  |  | P02 | D-B | EART | SC | CN |
| ContractNo_C470 |  | Install Landscape, Sod, Etc. - [Location] | 11d | 2025-04-16 | 2025-05-01 | ContractNo_C320 |  |  | 20d |  | Cal13-Planting 5d/12hol - Evergreen | P02 | D-B | SITE | SC | CN |
|  | StpD | **Step D** |  |  |  |  |  |  |  |  |  |  |  |  |  |  |
|  | Ph3 | **Stage 3** |  |  |  |  |  |  |  |  |  |  |  |  |  |  |
|  | StpA | **Step A** |  |  |  |  |  |  |  |  |  |  |  |  |  |  |
|  | StpB | **Step B** |  |  |  |  |  |  |  |  |  |  |  |  |  |  |
|  | StpC | **Step C** |  |  |  |  |  |  |  |  |  |  |  |  |  |  |
|  | StpD | **Step D** |  |  |  |  |  |  |  |  |  |  |  |  |  |  |
|  | Ph4 | **Stage 4** |  |  |  |  |  |  |  |  |  |  |  |  |  |  |
|  | StpA | **Step A** |  |  |  |  |  |  |  |  |  |  |  |  |  |  |
|  | StpB | **Step B** |  |  |  |  |  |  |  |  |  |  |  |  |  |  |
|  | StpC | **Step C** |  |  |  |  |  |  |  |  |  |  |  |  |  |  |
|  | StpD | **Step D** |  |  |  |  |  |  |  |  |  |  |  |  |  |  |
|  | Ph5 | **Stage 5** |  |  |  |  |  |  |  |  |  |  |  |  |  |  |
|  | StpA | **Step A** |  |  |  |  |  |  |  |  |  |  |  |  |  |  |
|  | StpB | **Step B** |  |  |  |  |  |  |  |  |  |  |  |  |  |  |
|  | StpC | **Step C** |  |  |  |  |  |  |  |  |  |  |  |  |  |  |
|  | StpD | **Step D** |  |  |  |  |  |  |  |  |  |  |  |  |  |  |
|  | Clo | **Close-Out** |  | 2025-04-24 | 2025-07-08 |  |  |  |  |  |  |  |  |  |  |  |
| ContractNo_C340 |  | MassDOT Inspection & Generate Punchlist | 21d | 2025-04-24 | 2025-05-22 | ContractNo_MS03 | 2025-04-24 | 2025-05-14 | 0d |  | Cal03A - 7d/8hr/No Holidays | GN | DOT | NA | NS | CL |
| ContractNo_C360 |  | Prepare & Submit Remaining Project Documentation | 20d | 2025-04-24 | 2025-05-21 | ContractNo_MS03 |  |  | 21d |  |  | GN | D-B | NA | NS | CL |
| ContractNo_C330 |  | Complete Punchlist & Demobilize | 30d | 2025-05-23 | 2025-07-08 | ContractNo_MS04, ContractNo_C340, ContractNo_MS02 | 2025-05-23 | 2025-06-21 | 0d |  | Cal03A - 7d/8hr/No Holidays | GN | D-B | NA | NS | CL |

| ID | WBS | Activity | Duration | Start | Finish | Total float | Calendar | Resources | Cost | CST-SubPhase | CST-Responsibility | CST-Type | CST-Step | CST-Phase |
| --- | --- | --- | --- | --- | --- | --- | --- | --- | --- | --- | --- | --- | --- | --- |
|  | Pla | **Placeholder** |  | 2023-01-01 | 2024-11-30 |  |  |  |  |  |  |  |  |  |
| ContractNo_CAL04 |  | Cal04-7d/24hr, No Holidays (Milestones) | 100d | 2023-01-01 | 2023-04-11 | 819.67d | Cal04-7d/24Hr/No Hol (Milestones) |  |  | CP | NA | NA | NS | PL |
| ContractNo_CAL03A |  | Cal03A-7d/8hr/No Holidays | 100d | 2023-01-01 | 2023-04-10 | 820d | Cal03A - 7d/8hr/No Holidays |  |  |  |  |  |  |  |
| ContractNo_CAL03 |  | Cal03-7D/8Hr, 12 Hol | 100d | 2023-01-02 | 2023-04-13 | 789d | Cal03-7d/8hr/12hol |  |  | CP | NA | NA | NS | PL |
| ContractNo_CAL08 |  | Cal08-7D/8Hr, 12 Hol - Mjr Rdwy | 100d | 2023-01-02 | 2023-04-20 | 722d | Cal08-7d/8hr/12hol-Mjr Rdwy |  |  | CP | NA | NA | NS | PL |
| ContractNo_C&RP |  | Cost & Resource Placeholder | 100d | 2023-01-03 | 2023-05-25 | 527d |  | Bid Item Value [40 h]; Bid Item Value [800 h] | 50,000 | CP | NA | NA | NS | PL |
| ContractNo_CAL01 |  | Cal01-5D/8Hr, 12 Hol | 100d | 2023-01-03 | 2023-05-25 | 527d |  |  |  | CP | NA | NA | NS | PL |
| ContractNo_CAL02 |  | Cal02-6D/8Hr, 12 Hol | 100d | 2023-01-03 | 2023-05-02 | 657d | Cal02-6d/8hr/12hol |  |  | CP | NA | NA | NS | PL |
| ContractNo_CAL06 |  | Cal06-5D/8Hr, 12 Hol - Mjr Rdwy | 100d | 2023-01-03 | 2023-05-30 | 506d | Cal06-5d/8hr/12hol-Mjr Rdwy |  |  | CP | NA | NA | NS | PL |
| ContractNo_CAL07 |  | Cal07-6D/8Hr, 12 Hol - Mjr Rdwy | 100d | 2023-01-03 | 2023-05-05 | 612d | Cal07-6d/8hr/12hol-MjrRdwy |  |  | CP | NA | NA | NS | PL |
| ContractNo_CAL10 |  | Cal10-Winter Ineff, 5D/12 Hol | 100d | 2023-01-03 | 2023-06-16 | 472d | Cal10-Wntr Ineff 5d/12hol |  |  | CP | NA | NA | NS | PL |
| ContractNo_CAL11A |  | Cal11A-Winter Shut 5D/8Hr, 12Hol - Mjr Rdwy | 100d | 2023-01-03 | 2023-05-30 | 365d | Cal11A-Wntr Shut 5d/12hol-Mjr Rdwy |  |  | CP | NA | NA | NS | PL |
| ContractNo_CAL12A |  | Cal12A-Paving, 5D/12 Hol - Mjr Rdwy | 100d | 2023-01-03 | 2023-05-30 | 329d | Cal12A-Paving 5d/12hol-Mjr Rdwy |  |  | CP | NA | NA | NS | PL |
| ContractNo_CAL16 |  | Cal16-Water Access 2, 5D/12Hol | 100d | 2023-01-03 | 2023-09-07 | 251d | Cal16- Wtr Acc 2-5d/12hol |  |  | CP | NA | NA | NS | PL |
| ContractNo_CAL05 |  | Cal05-MBTA Night No Hol | 100d | 2023-01-03 | 2023-05-25 | 527d | Cal05-MBTA Night/12hol |  |  | CP | NA | NA | NS | PL |
| ContractNo_CAL18 |  | Cal18-Weekend Shutdown | 100d | 2023-01-06 | 2023-05-05 | 634.25d | Cal18 - Weekend Shutdown |  |  | CP | NA | NA | NS | PL |
| ContractNo_CAL19 |  | Cal19-Saturdays Only (Advertise) | 100d | 2023-01-07 | 2024-11-30 | 31d | Cal19 - Saturday Only (Advert) |  |  |  |  |  |  |  |
| ContractNo_CAL11 |  | Cal11-Winter Shut 5D/8Hr, 12Hol | 100d | 2023-03-16 | 2023-08-08 | 334d | Cal11-Wntr Shut 5d/12hol |  |  | CP | NA | NA | NS | PL |
| ContractNo_CAL14 |  | Cal14-Planting, 5D/12Hol - Deciduous | 100d | 2023-03-21 | 2023-11-28 | 153d | Cal14-Planting 5d/12hol - Deciduous |  |  | CP | NA | NA | NS | PL |
| ContractNo_CAL12 |  | Cal12-Paving, 5D/12 Hol | 100d | 2023-04-03 | 2023-08-24 | 280d | Cal12-Paving 5d/12hol |  |  | CP | NA | NA | NS | PL |
| ContractNo_CAL13 |  | Cal13-Planting, 5D/12Hol - Evergreen | 100d | 2023-04-18 | 2024-05-23 | 77d | Cal13-Planting 5d/12hol - Evergreen |  |  | CP | NA | NA | NS | PL |
| ContractNo_CAL17 |  | Cal17 - Reclaimation - 5d/12hol | 100d | 2023-04-18 | 2023-09-08 | 205d | Cal17 - Reclaimation - 5d/12hol |  |  | CP | NA | NA | NS | PL |
| ContractNo_CAL15 |  | Cal15-Water Access1, 5D/12Hol | 100d | 2023-06-01 | 2024-06-25 | 92d | Cal15-Wtr Acc 1-5d/12hol |  |  | CP | NA | NA | NS | PL |
|  | Deleted | **Deleted Activities** |  |  |  |  |  |  |  |  |  |  |  |  |

## Activity codes

| Code | Value | Meaning |
| --- | --- | --- |
| CST-Phase | CL | Close Out |
| CST-Phase | CN | Construction |
| CST-Phase | MS | Milestones |
| CST-Phase | PC | Preconstruction |
| CST-Phase | PL | Placeholder |
| CST-Phase | PR | D-B Procurement |
| CST-Phase | UR | Utility Relocation |
| CST-Responsibility | ACO | Army Corp of Engineers (ACOE) |
| CST-Responsibility | D-B | Design-Builder |
| CST-Responsibility | DEP | Dept. of Enviromental Protection |
| CST-Responsibility | DOT | MassDOT |
| CST-Responsibility | FED | Federal Highway Admin |
| CST-Responsibility | NA | Not Applicable |
| CST-Responsibility | NMFS | National Marine Fishery Service |
| CST-Responsibility | UKE | Utility: Keyspan-Electric |
| CST-Step | BLS | Baseline Schedule |
| CST-Step | NS | No Step |
| CST-Step | SA | Step A |
| CST-Step | SB | Step B |
| CST-Step | SC | Step C |
| CST-Step | SD | Step D |
| CST-Step | STL | Steel Beams |
| CST-Step | URP | Utility Relocation & Coordination Plan |
| CST-SubPhase | CP | Calendar Placeholder |
| CST-SubPhase | DE | Design |
| CST-SubPhase | DU | Contract Durations |
| CST-SubPhase | GN | General |
| CST-SubPhase | P01 | Phase 1 |
| CST-SubPhase | P02 | Phase 2 |
| CST-SubPhase | P03 | Phase 3 |
| CST-SubPhase | PE | Permit |
| CST-SubPhase | PR | Procurement |
| CST-Type | CONC | Concrete |
| CST-Type | DEMO | Demolition |
| CST-Type | DES | Design |
| CST-Type | EART | Earthwork |
| CST-Type | NA | Not Applicable |
| CST-Type | PRO | Procurement |
| CST-Type | SITE | Site Work |
| CST-Type | STEE | Steel |
| CST-Type | UTIL | Utility |
| CST-Type | WATE | Water Control |
